# 3GPP_Work Plan

Schedule from MS Project, 2000-01-03 to 2005-11-02, A marks actual dates.

## Calendars

- Standard: Mon-Fri 08:00-12:00, 13:00-17:00; Sat-Sun off.

## Resources

| Resource |
| --- |
| NP |
| N1 |
| N2 |
| N3 |
| N4 |
| N5 |
| TP |
| T1 |
| T2 |
| T3 |
| RP |
| R1 |
| R2 |
| R3 |
| R4 |
| SP |
| S1 |
| S2 |
| S3 |
| S4 |
| S5 |
| PCG |
| GP |
| No |
| CN4 |
| ? |
| WG G2 |
| G2 |
| G1 |
| G4 |
| G3 |
| All |
| Generic |
| MLST |
| G5 |
| S3, G2 |
| WG T2 |
| GP,G1 |
| G4,G5 |
| OMA |
| GP-G2 |
| Yes |

## Schedule

| ID | WBS | Task | Duration | Start | Finish | Complete | Remaining | Baseline start | Baseline finish | Baseline duration | Total slack | Constraint | Resources | Work | Actual work | Text6 | Text9 | Text1 | Text4 | Text5 | Text7 | Text8 | Text11 | Text10 | Text2 | Text3 | Text12 |
| --- | --- | --- | --- | --- | --- | --- | --- | --- | --- | --- | --- | --- | --- | --- | --- | --- | --- | --- | --- | --- | --- | --- | --- | --- | --- | --- | --- |
| 1 | 1 | VERSION 2004 April 14th | 1d | 2000-01-03 | 2000-01-03 |  |  | 2000-01-03 | 2000-01-03 | 1d | 1522d |  |  |  |  | Rel | 2044 |  |  |  |  |  |  |  |  |  |  |
| 2 | 2 | "CTRL + a" to display all the 3GPP fields | 1d | 2000-01-03 | 2000-01-03 |  |  | 2000-01-03 | 2000-01-03 | 1d | 1294d |  |  |  |  |  | 1462 |  |  |  |  |  |  |  |  |  |  |
| 3 | 3 | Content of Rel-6 and after. Not frozen. | 1d | 2000-01-03 | 2000-01-03 |  |  | 2000-01-03 | 2000-01-03 | 1d | 1294d |  |  |  |  | Rel | 2058 |  |  |  |  |  |  |  |  |  |  |
| 5 | 4 | Evolutions of the transport in the UTRAN | 218d | 2003-03-03 | 2003-12-31 |  |  |  |  |  | 512d | start no earlier than 2003-03-03 | RP | 1744h |  | NA | Feat | ETRAN | Francois Courau, Alcatel | francois.courau@alcatel.fr | TSG | MCC_RAN | Generic |  |  |  |  |
| 6 | 8 | **Improvements of Radio Interface** | 1068d | 2000-08-14 A | 2004-09-15 | 78% | 229.66d | 2000-08-14 | 2004-03-19 | 940d? | 295d |  | RP | 38080h | 29691.5h | Rel-6 |  | RInImp |  |  | TSG |  |  |  |  |  |  |
| 7 | 5.1 | Improvement of inter-frequency and inter-system measurement | 968d | 2001-01-01 A | 2004-09-15 | 50% | 484d |  |  |  | 295d | finish no earlier than 2004-09-15 | R1 | 7744h | 3872h | Rel-6 | BB | RInImp-IfIsM | Antti Toskala, Nokia | antti.toskala@nokia.com | TSG | MCC RAN | Active | 1216 |  |  |  |
| 8 | 5.2 | Improving Receiver Performance Requirements for the FDD UE | 401d | 2002-03-08 A | 2003-09-19 A | 100% |  |  |  |  |  | start no earlier than 2002-03-08 | R4 | 3208h | 3208h | Rel-6 | BB | RInImp-UERecPerf | Shimon Moshavi, Intel | shimon.moshavi@INTEL.COM | TSG |  | Active | 1216 |  |  |  |
| 9 | 8.2 | **Base station classification** | 603d | 2000-08-14 A | 2002-12-04 A | 100% |  | 2000-08-14 | 2002-12-04 | 603d |  |  | R4 | 9648h | 9648h | Rel-6 |  | RInImp-BSClass |  |  | TSG |  |  |  |  |  |  |
| 10 | 8.2.1 | FDD Base station classification | 603d | 2000-08-14 A | 2002-12-04 A | 100% |  | 2000-08-14 | 2002-12-04 | 603d |  | finish no earlier than 2002-12-04 | R4 | 4824h | 4824h | Rel-6 | 1476 | RInImp-BSClass-FDD | A. Toskala, Nokia |  | TSG |  |  |  | BaAs |  |  |
| 11 | 5.4 | UMTS-850 | 266d | 2002-12-06 A | 2003-12-12 A | 100% |  |  |  |  |  | finish no earlier than 2003-12-15 | R4 | 2128h | 2128h | Rel-6 | BB | RInImp-UMTS850 | Don Zelmer, Cingular | don.zelmer@cingular.com | TSG | MCC_RAN | Active | 1216 |  |  |  |
| 12 | 5.5 | DS-CDMA introduction in the 800 MHz band | 196d | 2003-03-14 A | 2003-12-12 A | 100% |  |  |  |  |  | finish no earlier than 2003-12-15 | R4 | 1568h | 1568h | Rel-6 | BB | RInImp-UMTS800 | Takehiro Nakamura, NTT DoCoMo | takehiro@wsp.yrp.nttdocomo.co.jp | TSG | MCC_RAN | Active | 1216 |  |  |  |
| 13 | 5.6 | UMTS 1.7/2.1 GHz | 261d | 2003-03-14 A | 2004-03-12 A | 100% |  |  |  |  |  | finish no earlier than 2004-03-15 | R4 | 2088h | 2088h | Rel-6 | BB | RInImp-UMTS1721 | Jussi Numminen, Nokia | jussi.numminen@NOKIA.COM | TSG | MCC RAN | Active | 1216 |  |  |  |
| 14 | 5.7 | **Improved Receiver Performance Requirements for HSDPA** | 197d | 2003-12-15 A | 2004-09-14 | 30% | 137.9d |  |  |  | 296d |  | R4 | 3152h | 472.8h | Rel-6 |  | RInImp-HSPerf | Jussi Numminen, Nokia | jussi.numminen@NOKIA.COM | TSG | MCC RAN |  |  |  |  |  |
| 15 | 5.7.1 | Performance Requirements of Receive Diversity for HSDPA | 197d | 2003-12-15 A | 2004-09-14 | 30% | 137.9d |  |  |  | 296d | start no earlier than 2003-12-15 | R4 | 1576h | 472.8h | Rel-6 |  | RInImp-HSPerf-RxDiv | Takehiro Nakamura (NTT DoCoMo) | takehiro@wsp.yrp.nttdocomo.co.jp | TSG | MCC RAN |  |  |  | TS25.101 |  |
| 16 | 6 | **RAN Feasibility Studies** | 1197d | 2000-08-14 A | 2005-03-15 | 67% | 396.27d |  |  |  | 166d |  | RP | 46152h | 26479.7h | Rel-6 |  |  |  |  |  |  |  |  |  |  |  |
| 17 | 6.1 | FS on Radio link performance enhancements | 1002d | 2000-08-14 A | 2004-06-15 | 70% | 300.6d |  |  |  | 361d | finish no earlier than 2004-06-15 | R1 | 8016h | 5611.2h | Rel-6 | SI | RInImp-Rlperf | Antti Toskala, Nokia Networks | antti.toskala@nokia.com | TSG | MCC_RAN | Active | 1216 |  |  |  |
| 18 | 6.2 | FS on UTRA WideBand Distribution Systems | 852d | 2001-03-12 A | 2004-06-15 | 60% | 340.8d |  |  |  | 361d | finish no earlier than 2004-06-15 | R4 | 6816h | 4089.6h | Rel-6 | SI | RInImp-WDS | Andrea Casini, Tekmar Sistemi | carlo.matarasso@andrew.com | TSG | MCC_RAN | Active | 1216 |  |  |  |
| 19 | 6.3 | FS on Improvement of inter-frequency and inter-system measurements for 1.28 Mcps TDD | 461d | 2001-12-14 A | 2003-09-19 A | 100% |  |  |  |  |  | start no earlier than 2001-12-14 | R1 | 3688h | 3688h | Rel-6 | SI | RInImp-IfIsMLCR | Li Xiao Qiang, SAMSUNG | xqli@samsung.co.kr | TSG |  | Active | 1216 |  |  | 10 |
| 20 | 6.4 | FS for the analysis of OFDM for UTRAN enhancement | 526d | 2002-06-10 A | 2004-06-14 | 75% | 131.5d |  |  |  | 362d | start no earlier than 2002-06-10 | R1 | 4208h | 3156h | Rel-6 | SI | RInImp-FSOFDM | Sarah Boumendil, Nortel | boumendi@nortelnetworks.com | TSG | MCC_RAN | Active | 1216 |  |  | 11 |
| 21 | 6.5 | FS on Uplink Enhancements for Dedicated Transport Channels | 396d | 2002-09-06 A | 2004-03-12 A | 100% |  |  |  |  |  | finish no earlier than 2004-03-12 | R1 | 3168h | 3168h | Rel-6 | SI | RInImp-FSUpDTrCh | Karri Ranta-aho, Nokia | Karri.Ranta-aho@nokia.com | TSG | MCC_RAN | Active | 1216 |  |  | 12 |
| 22 | 6.6 | FS on Analysis on Higher Chip Rates for UTRA TDD evolutions | 462d | 2002-09-06 A | 2004-06-14 | 80% | 92.4d |  |  |  | 362d | finish no earlier than 2004-06-14 | R1 | 3696h | 2956.8h | Rel-6 | SI | RInImp-FSVHCRTDD | Tim Wilkinson, IPWireless | mbeale@ipwireless.com | TSG | MCC_RAN | Active | 1216 |  |  | 13 |
| 23 | 6.7 | FS on Low Output Powers for general purpose FDD BSs | 128d | 2003-06-13 A | 2004-03-12 A | 100% |  |  |  |  |  | finish no earlier than 2004-03-12 | R3 | 1024h | 1024h | Rel-6 | SI | RInImp-FSLoPw | Ana Burgos, Telefonica | burgos_a@tsm.es | TSG | MCC_RAN | Active | 1216 |  |  | 14 |
| 24 | 6.8 | FS on Uplink enhancements for UTRA TDD | 333d | 2003-06-06 A | 2004-09-14 | 10% | 299.7d |  |  |  | 296d | finish no earlier than 2004-09-14 | R1 | 2664h | 266.4h | Rel-6 | SI | RInImp-FSUpEnhTDD | Marian Rudolf, Interdigital | Marian.Rudolf@InterDigital.com | TSG | MCC_RAN | Active | 1216 |  |  | 15 |
| 25 | 8.8 | FS on UE antenna efficiency test methods performance requirements (2) | 131d | 2002-03-08 A | 2002-09-06 A | 100% |  | 2002-03-08 | 2002-09-06 | 131d |  | finish no earlier than 2002-09-06 | R4 | 1048h | 1048h | Rel-6 |  | RInImp-UEAnTM2 | Alf Ahlström, Allgon |  | TSG |  |  |  |  |  |  |
| 26 | 9.4 | FS on the evolution of the UTRAN architecture | 657d | 2002-09-09 A | 2005-03-15 | 28% | 473.04d | 2002-09-09 | 2003-12-19 | 335d | 166d | finish no earlier than 2005-03-15 | R3 | 5256h | 1471.68h | Rel-6 |  | RANimp-FSEvo | Woonhee Hwang, Nokia | Antti.Toskala@nokia.com | TSG | MCC_RAN |  |  |  |  |  |

Notes:
- 5: Generic feature
- 6: This is a generic feature without particular end date
- 25: The RInImp-UEAnTM FS was re-opened at TSG RAN#15 upon request from WG4
- 26: Work stopped until completion of MBMS in RAN3

| ID | WBS | Task | Duration | Start | Finish | Complete | Remaining | Baseline start | Baseline finish | Baseline duration | Total slack | Constraint | Resources | Work | Actual work | Text1 | Text4 | Text5 | Text6 | Text7 | Text8 | Text9 | Text10 | Text11 | Text3 | Text12 | Text2 |
| --- | --- | --- | --- | --- | --- | --- | --- | --- | --- | --- | --- | --- | --- | --- | --- | --- | --- | --- | --- | --- | --- | --- | --- | --- | --- | --- | --- |
| 27 | 8.5 | **Multiple Input Multiple Output antennas (MIMO)** | 523d? | 2003-03-14 A | 2005-03-15 | 16% | 437.84d? | 2003-03-14 | 2004-12-17 | 461d? | 166d |  | R1 | 16256h | 4064.8h | MIMO | Howard Huang, Lucent | hchuang@lucent.com | Rel-6 | TSG | MCC_RAN | 2468 |  |  |  |  |  |
| 28 | 7.1 | MIMO - Physical layer | 393d? | 2003-09-12 A | 2005-03-15 | 50% | 196.5d? | 2003-03-14 | 2004-03-19 | 266d? | 166d | finish no earlier than 2004-09-14 | R1 | 3144h | 1572h | MIMO-Phys | Howard Huang, Lucent | hchuang@lucent.com | Rel-6 | TSG | MCC RAN |  |  |  |  |  |  |
| 29 | 7.2 | MIMO - Layer 2,3 aspects | 329d? | 2003-09-12 | 2004-12-15 |  |  | 2003-09-12 | 2004-03-19 | 136d? | 230d | finish no earlier than 2004-12-15 | R2 | 2632h |  | MIMO-L23 | Howard Huang, Lucent | hchuang@lucent.com | Rel-6 | TSG | MCC RAN |  |  |  |  |  |  |
| 30 | 7.3 | MIMO - Iub/Iur Protocol Aspects | 459d? | 2003-03-14 | 2004-12-15 |  |  | 2003-03-14 | 2003-09-19 | 136d? | 230d | finish no earlier than 2004-12-15 | R3 | 3672h |  | MIMO-IurIub | Howard Huang, Lucent | hchuang@lucent.com | Rel-6 | TSG | MCC RAN |  |  |  |  |  |  |
| 31 | 7.4 | MIMO - RF Radio Transmission/Reception, System Performance Requirements and Conformance Testing | 328d? | 2003-12-12 A | 2005-03-15 | 15% | 278.8d? | 2003-12-12 | 2004-12-17 | 266d? | 166d | finish no earlier than 2005-03-15 | R4 | 2624h | 393.6h | MIMO-RF | Man Hung Ng, Lucent | ngm@lucent.com | Rel-6 | TSG | MCC RAN |  |  |  |  |  |  |
| 32 | 8 | **FDD Enhanced Uplink** | 327d | 2004-03-15 | 2005-06-15 |  |  |  |  |  | 101d |  | RP | 9968h |  | EDCH | Joakim Bergström (Ericsson) |  |  | TSG | MCC RAN | Feat | 20003 | Active |  |  |  |
| 33 | 8.1 | EDCH - Stage 2 | 1d | 2004-03-15 | 2004-03-15 |  |  |  |  |  | 427d | start no earlier than 2004-03-15 | R2 | 8h |  | EDCH-Stage2 |  |  |  | TSG |  |  |  |  | New TR |  |  |
| 34 | 8.2 | EDCH - Physical Layer | 197d | 2004-03-15 | 2004-12-15 |  |  |  |  |  | 231d | finish no earlier than 2004-12-15 | R1 | 1576h |  | EDCH-Phys | Karri Ranta-aho (Nokia) |  |  | TSG | MCC RAN | BB | 20003 | Active | TS25.211, 25.212, 25.213, 25.214, 25.215 | 26 |  |
| 35 | 8.3 | EDCH - Layer 2 and 3 Protocol Aspects | 197d | 2004-03-15 | 2004-12-15 |  |  |  |  |  | 231d | finish no earlier than 2004-12-15 | R2 | 1576h |  | EDCH-L23 | Joakim Bergström (Ericsson) |  |  | TSG | MCC RAN | BB | 20003 | Active | TS25.301, 25.302, 25.306, 25.321, 25.331 | 27 |  |
| 36 | 8.4 | EDCH - UTRAN Iub/Iur Protocol Aspects | 197d | 2004-03-15 | 2004-12-15 |  |  |  |  |  | 231d | finish no earlier than 2004-12-15 | R3 | 1576h |  | EDCH-IurIub | Saso Stojanovski (Nortel) |  |  | TSG | MCC RAN | BB | 20003 | Active | TS25.401, 25.420, 25.423, 25.430, 25.433 | 28 |  |
| 37 | 8.5 | EDCH - RF Radio Transmission/ Reception, System Performance Requirements and Conformance Testing | 327d | 2004-03-15 | 2005-06-15 |  |  |  |  |  | 101d | finish no earlier than 2005-06-15 | R4 | 2616h |  | EDCH-RF | Thomas Unshelm (Ericsson) |  |  | TSG | MCC RAN | BB | 20003 | Active | TS25.101, 25.104, 25.133, 25.141 | 29 |  |
| 38 | 9 | **RAN improvements** | 712d? | 2002-03-25 A | 2004-12-15 | 42% | 414.14d? | 2001-12-14 | 2004-03-19 | 591d? | 231d |  | RP | 32456h | 11517.2h | RANimp |  |  | Rel-6 | TSG | MCC_RAN |  |  |  |  |  |  |
| 39 | 9.2 | **RAB support enhancement** | 458d? | 2003-03-14 A | 2004-12-15 | 13% | 396.52d? | 2003-03-14 | 2004-03-19 | 266d? | 231d |  | R2 | 10488h | 1128.8h | RANimp-RABSE | Juha Mikola, Nokia | juha.mikola@nokia.com | Rel-6 | TSG | MCC RAN | 624 |  |  |  |  | BaAS |
| 40 | 9.1.1 | Iu enhancements for IMS support in RAN | 458d? | 2003-03-14 A | 2004-12-15 | 25% | 343.5d? | 2003-03-14 | 2004-03-19 | 266d? | 231d | finish no earlier than 2004-12-15 | R3 | 3664h | 916h | RANimp-RABSE-IuEnhIMS | Phillipe Godin, Nortel | Philippe.Godin@nortelnetworks.com | Rel-6 | TSG | MCC RAN |  |  |  |  |  |  |
| 41 | 9.1.2 | Optimisation of downlink channelisation code utilisation | 198d | 2004-03-12 | 2004-12-15 |  |  |  |  |  | 231d | finish no earlier than 2004-12-15 | R1 | 1584h |  | RANimp-RABSE-CodeOptFDD | Sarah Boumendil (Nortel Networks) | boumendi@nortelnetworks.com |  | TSG | MCC RAN | WT | 624 | Active |  |  |  |
| 42 | 9.1.3 | Optimisation of channelisation code utilisation for TDD | 197d | 2004-03-15 | 2004-12-15 |  |  |  |  |  | 231d | finish no earlier than 2004-12-15 | R1 | 1576h |  | RANimp-RABSE-CodeOptTDD | Nicholas Anderson (IPWireless) |  |  | TSG | MCC RAN | WT | 624 | Active |  |  |  |
| 43 | 9.3 | DELETE: Improvement of RRM across RNS and RNS/BSS | 445d | 2002-03-25 A | 2003-12-05 | 35% | 289.25d | 2002-03-25 | 2003-12-05 | 445d | 498d | finish no earlier than 2003-12-05 | R3 | 3560h | 1246h | RANimp-RRM1 | Antti Toskala, Nokia | antti.toskala@nokia.com | Rel-6 | TSG |  |  |  |  |  |  |  |
| 44 | 9.1 | Beamforming Enhancements | 66d | 2003-09-19 A | 2003-12-19 A | 100% |  | 2001-12-14 | 2003-09-19 | 461d |  | finish no earlier than 2004-03-12 | R1 | 528h | 528h | RANimp-BFE | Jussi Kähtävä, Nokia | jussi.kahtava@nokia.com | Rel-6 | TSG | MCC_RAN |  |  |  |  |  |  |
| 45 | 9.4 | **Rel6 RRM optimization for Iur and Iub** | 126d | 2003-09-19 A | 2004-03-12 | 99% | 0d | 2002-12-06 | 2003-09-19 | 206d? | 0d |  | R3 | 2016h | 1008h | RANimp-RRMopt | Gert-Jan van Lieshout, Ericsson | Gert-Jan.van.Lieshout@eln.ericsson.se | Rel-6 | TSG | MCC_RAN |  |  |  |  |  | BaAS |
| 46 | 9.4.1 | Improved access to User Equipment (UE) measurement data for Controlling Radio Network Controller (CRNC) to support Time Division Duplex (TDD) Radio Resource Management (RRM) | 126d | 2003-09-19 A | 2004-03-12 A | 100% |  |  |  |  |  | finish no earlier than 2004-03-15 | R3 | 1008h | 1008h | RANimp-RRMopt-UEMsD | Jim Miller, Interdigital | jim.miller@interdigital.com | Rel-6 | TSG | MCC RAN | WT | 23012 | Active | TS25.423 | 22 |  |
| 47 | 9.5 | Remote Control of Electrical Tilting Antennas | 394d? | 2003-03-14 A | 2004-09-15 | 45% | 216.7d? | 2003-03-14 | 2003-12-05 | 191d? | 295d | finish no earlier than 2004-09-15 | R3 | 3152h | 1418.4h | RANimp-TiltAnt | Andreas Hauser, Vodafone | Andreas.Hauser@vodafone.com | Rel-6 | TSG | MCC_RAN |  |  |  |  |  |  |
| 48 | 9.6 | NEW - OAM&P impacts of Remote control of Electrical Tilting antennas | 145d | 2004-02-27 A | 2004-09-16 | 10% | 130.5d |  |  |  | 294d | finish no earlier than 2004-09-16 | S5 | 1160h | 116h | RANimp-TiltAnt-OAM | John MUDGE, Vodafone | john.mudge@vodafone.co.uk | Rel-6 | WG | Adrian |  |  |  | 32.804, 32.xyz |  |  |
| 49 | 9.7 | Network Assisted Cell Change (NACC) from UTRAN to GERAN - network-side aspects | 462d? | 2002-09-09 A | 2004-06-15 | 50% | 231d? | 2003-06-13 | 2003-12-19 | 136d? | 361d | finish no earlier than 2004-06-15 | R3 | 3696h | 1848h | RANimp-NACC | Brendan McWilliams, Vodafone | Brendan.McWilliams@gb.vodafone.co.uk | Rel-6 | TSG | MCC_RAN |  |  |  |  |  |  |
| 50 | 9.8 | FS of the improved access to UE measurement data for CRNC to support TDD RRM | 270d? | 2002-12-06 A | 2003-12-18 A | 100% |  | 2002-12-06 | 2003-09-19 | 206d? |  | finish no earlier than 2003-09-19 | R3 | 2160h | 2160h | RANimp-RRMopt-FSUEMsD | Jim Miller, Interdigital | jim.miller@interdigital.com | Rel-6 | TSG |  |  |  |  |  |  |  |

Notes:
- 38: Generic feature
- 39: This is a building block without particular end date
- 40: Completiond 6 months after SA WG2 finishes its block
- 48: az: WID approved at SA5#37 (02/2004)

| ID | WBS | Task | Duration | Start | Finish | Complete | Remaining | Baseline start | Baseline finish | Baseline duration | Total slack | Constraint | Resources | Work | Actual work | Text1 | Text4 | Text6 | Text7 | Text2 | Text3 | Text9 | Text5 | Text8 |
| --- | --- | --- | --- | --- | --- | --- | --- | --- | --- | --- | --- | --- | --- | --- | --- | --- | --- | --- | --- | --- | --- | --- | --- | --- |
| 51 | 10 | **PS domain and IMS impacts for supporting IMS Emergency calls** | 1255d? | 2000-08-14 A | 2005-06-03 | 30% | 880.21d? | 2000-08-14 | 2003-12-12 | 870d? | 108d |  | S2 | 47592h | 12328.6h | EMC1 | Rainer Liebhart | Rel-6 | TSG |  |  |  |  |  |
| 52 | 10.1.1 | Service Requirements for IP-based emergency calls | 725d | 2000-09-18 A | 2003-06-27 | 90% | 72.5d | 2000-09-18 | 2003-06-27 | 725d | 613d | finish no earlier than 2003-06-27 | S1 | 5800h | 5220h |  |  | Rel-6 |  | CCaR | 22.976 | 1314 |  |  |
| 53 | 10.2 | Stage 2 | 460d? | 2003-02-26 A | 2004-11-30 | 53% | 216.2d? | 2003-02-26 | 2003-09-18 | 147d? | 241d | finish no earlier than 2004-11-30 | S2 | 3680h | 1950.4h |  | Miikka Poikselka, Nokia | Rel-6 | TSG |  |  |  |  |  |
| 54 | 10.1 | **Emergency Call Enhancements for IP& PS Based Calls – stage 3** | 1255d | 2000-08-14 A | 2005-06-03 | 8% | 1156.47d | 2000-08-14 | 2003-12-12 | 870d | 108d |  | N1 | 28272h | 2219.53h |  | Mr Atle Monrad, Ericsson | Rel-6 |  | CCaR |  | 1653 | Atle.Monrad@eto.ericsson.se |  |
| 55 | 10.1.2 | SIP emergency calls and packet emergency calls signalling flows | 1209d | 2000-10-17 A | 2005-06-03 | 16% | 1015.56d | 2000-10-17 | 2003-12-12 | 824d | 108d | finish no earlier than 2005-06-03 | N1 | 9672h | 1547.52h |  | Mr Atle Monrad, Ericsson | Rel-6 |  | CCaR | TS 24.228 | 1315 | Atle.Monrad@eto.ericsson.se |  |
| 56 | 10.1.5 | Stage 3 for emergency calls and packet emergency calls in general | 1255d | 2000-08-14 | 2005-06-03 |  |  | 2000-08-14 | 2003-12-12 | 870d | 108d | finish no earlier than 2005-06-03 | N1 | 10040h |  |  | Mr Atle Monrad, Ericsson | Rel-6 |  | CCaR | TS 24.229 | 1646 | Atle.Monrad@eto.ericsson.se |  |
| 57 | 12 | **Location Services enhancements 2** | 1058d? | 2000-08-28 A | 2004-09-15 | 66% | 361.32d? | 2000-08-28 | 2004-03-19 | 930d? | 295d |  | S2 | 78200h | 47442.8h | LCS2 |  | Rel-6 | TSG |  |  |  |  | Sang-Ui |
| 58 | 12.1 | **Improvement on Le interface** | 397d? | 2002-06-17 A | 2003-12-23 | 74% | 104.98d? | 2002-06-17 | 2003-12-23 | 397d? | 486d |  | S2 | 6776h | 4984.12h |  |  | Rel-6 | TSG |  |  |  |  |  |
| 59 | 11.1.1 | Stage 2 | 331d? | 2002-06-17 A | 2003-09-22 A | 100% |  | 2002-06-17 | 2003-09-22 | 331d? |  | start no earlier than 2002-06-17 | S2 | 2648h | 2648h |  |  | Rel-6 |  |  |  |  |  |  |
| 60 | 11.1.2 | Stage 3 in OMA - it impacts Mobile Location Protocol (MLP) | 119d? | 2003-07-10 | 2003-12-23 |  |  | 2003-07-10 | 2003-12-23 | 119d? | 486d | finish no earlier than 2003-12-23 | OMA | 952h |  |  |  | Rel-6 |  |  |  |  |  |  |
| 61 | 12.2 | **Enhanced support for anonymity and user privacy** | 382d? | 2002-07-08 A | 2003-12-23 | 68% | 121.55d? | 2002-07-08 | 2003-12-23 | 382d? | 486d |  | S2 | 6048h | 4072.03h |  |  | Rel-6 | TSG |  |  |  |  |  |
| 62 | 11.2.1 | Stage 2 | 255d? | 2002-07-08 A | 2003-06-27 A | 100% |  | 2002-07-08 | 2003-06-27 | 255d? |  | finish no earlier than 2003-06-27 | S2 | 2040h | 2040h |  |  | Rel-6 |  |  |  |  |  |  |
| 63 | 11.2.2 | Stage 3 in OMA (it impacts MLP and RLP) | 119d? | 2003-07-10 | 2003-12-23 |  |  | 2003-07-10 | 2003-12-23 | 119d? | 486d | finish no earlier than 2003-12-23 | OMA | 952h |  |  |  | Rel-6 |  |  |  |  |  |  |
| 64 | 12.3 | **Enhanced inter-GMLC interface** | 320d? | 2002-06-24 A | 2003-09-12 | 76% | 75.82d? | 2002-06-24 | 2003-09-12 | 320d? | 558d |  | S2 | 7240h | 5524.68h |  |  | Rel-6 | TSG |  |  |  |  |  |
| 65 | 11.3.1 | Stage 2 | 315d? | 2002-06-24 A | 2003-09-05 | 86% | 44.1d? | 2002-06-24 | 2003-09-05 | 315d? | 563d | finish no earlier than 2003-09-05 | S2 | 2520h | 2167.2h |  |  | Rel-6 |  |  |  |  |  |  |
| 66 | 11.3.2 | Stage 3 in OMA (definition of RLP and PCP) | 270d? | 2002-09-02 A | 2003-09-12 | 65% | 94.5d? | 2002-09-02 | 2003-09-12 | 270d? | 558d | finish no earlier than 2003-09-12 | OMA | 2160h | 1404h |  |  | Rel-6 |  |  |  |  |  |  |
| 67 | 12.4 | **Location Services support for IMS public identities** | 365d? | 2002-09-02 A | 2004-01-23 | 71% | 104.84d? | 2002-09-02 | 2003-12-19 | 340d? | 463d |  | S2 | 6560h | 4833.75h |  |  | Rel-6 | TSG |  |  |  |  |  |
| 68 | 11.4.1 | Stage 2 | 240d? | 2003-02-24 A | 2004-01-23 A | 100% |  | 2003-02-24 | 2003-12-19 | 215d? |  | finish no earlier than 2004-01-23 | S2 | 1920h | 1920h |  |  | Rel-6 |  |  |  |  |  |  |
| 69 | 11.4.2 | Stage 3 in OMA (impacts MLP, RLP and PCP) | 340d? | 2002-09-02 A | 2003-12-19 | 51% | 166.6d? | 2002-09-02 | 2003-12-19 | 340d? | 488d | finish no earlier than 2003-12-19 | OMA | 2720h | 1387.2h |  |  | Rel-6 |  |  |  |  |  |  |
| 70 | 12.5 | **New area event for location service triggering reports** | 587d? | 2002-06-03 A | 2004-08-31 | 69% | 181.33d? | 2002-06-03 | 2003-12-22 | 406d? | 306d |  | S2 | 9728h | 5709.63h |  |  | Rel-6 | TSG |  |  |  |  |  |
| 71 | 11.5.1 | Stage 2 | 280d? | 2002-06-03 A | 2003-06-27 A | 100% |  | 2002-06-03 | 2003-06-27 | 280d? |  | finish no earlier than 2003-06-27 | S2 | 2240h | 2240h |  |  | Rel-6 |  |  |  |  |  |  |
| 72 | 11.5.2 | Stage 3 for UE-CN signalling | 234d? | 2003-10-09 A | 2004-08-31 | 66% | 79.3d? | 2003-07-10 | 2003-12-22 | 118d? | 306d | finish no earlier than 2004-08-31 | N4 | 1872h | 1237.6h |  |  | Rel-6 |  |  |  |  |  |  |
| 73 | 11.5.3 | Stage 3 in OMA (impacts MLP, RLP and PCP) | 115d? | 2003-07-14 | 2003-12-19 |  |  | 2003-07-14 | 2003-12-19 | 115d? | 488d | finish no earlier than 2003-12-19 | OMA | 920h |  |  |  | Rel-6 |  |  |  |  |  |  |
| 74 | 12.6 | **FS on applicability of GALILEO for LCS** | 518d? | 2002-07-08 A | 2004-06-30 | 54% | 236.22d? | 2002-07-08 | 2004-03-19 | 445d? | 350d |  | S2 | 9248h | 3776.48h |  |  | Rel-6 |  |  |  |  |  |  |
| 75 | 11.6.1 | TR on Stage 2 (No contributions received, No feedback from other groups since May) | 518d? | 2002-07-08 A | 2004-06-30 | 67% | 170.94d? | 2002-07-08 | 2004-03-19 | 445d? | 350d | finish no earlier than 2004-06-30 | S2 | 4144h | 2776.48h |  |  | Rel-6 |  |  |  |  |  |  |
| 76 | 11.6.2 | GERAN review of the TR | 120d? | 2003-08-25 | 2004-02-06 |  |  | 2003-08-25 | 2003-12-12 | 80d? | 453d | finish no earlier than 2004-02-06 | GP | 960h |  |  |  | Rel-6 |  |  |  |  |  |  |

Notes:
- 72: 31/10/2003 work has started. Current stage 3 fullfills the requirements of stage 2. / 14/05/2004: Work is nearly finished. Work will be finished CN#25.

| ID | WBS | Task | Duration | Start | Finish | Complete | Remaining | Baseline start | Baseline finish | Baseline duration | Total slack | Constraint | Resources | Work | Actual work | Text1 | Text6 | Text7 | Text8 | Text4 | Text5 | Text9 | Text2 |
| --- | --- | --- | --- | --- | --- | --- | --- | --- | --- | --- | --- | --- | --- | --- | --- | --- | --- | --- | --- | --- | --- | --- | --- |
| 77 | 12.7 | **UE positioning** | 1058d? | 2000-08-28 A | 2004-09-15 | 62% | 402.25d? | 2000-08-28 | 2004-03-19 | 930d? | 295d |  | RP | 25736h | 14022.2h | LCS2-UEpos | Rel-6 | TSG | MCC_RAN |  |  |  |  |
| 78 | 12.7.1 | UE positioning enhancements - other methods | 805d | 2000-08-28 A | 2003-09-26 | 25% | 603.75d | 2000-08-28 | 2003-09-26 | 805d | 548d | start no earlier than 2000-08-28 | R2 | 6440h | 1610h | LCS2-UEpos-enh | Rel-6 | TSG | MCC_RAN | Meik Kottkamp, Siemens | Meik.Kottkamp@siemens.com | 2457 |  |
| 79 | 12.8 | Open SMLC-SRNC Interface within the UTRAN to support UTRAN Rel4 positioning methods | 700d? | 2001-01-15 A | 2003-09-19 A | 100% |  | 2001-01-15 | 2003-09-19 | 700d? |  | finish no earlier than 2003-09-19 | R2 | 5600h | 5600h | LCS-Rel4Pos | Rel-6 | TSG |  | Meik Kottkamp, Siemens | Meik.Kottkamp@siemens.com | 2475 |  |
| 80 | 11.7.3 | A-GPS minimum performance specification | 334d? | 2003-06-06 A | 2004-09-15 | 35% | 217.1d? | 2003-06-06 | 2004-03-19 | 206d? | 295d | finish no earlier than 2004-09-15 | R4 | 2672h | 935.2h | LCS-UEPos-AGPSPerf | Rel-6 | TSG | MCC_RAN | Donglin Shen, AT&T Wireless Services | donglin.shen@attws.com |  |  |
| 81 | 12.7.2 | FS on Enhancements to OTDOA Positioning using advanced blanking methods | 320d | 2002-07-01 A | 2003-09-19 A | 100% |  | 2002-07-01 | 2003-09-19 | 320d |  | finish no earlier than 2003-09-19 | R2 | 2560h | 2560h | LCS2-UEpos-FSBlank | Rel-6 | TSG |  | David Bartlett, Cambridge Positioning Systems | david.bartlett@cursor-system.com |  |  |
| 82 | 14 | **Security enhancements** | 903d? | 2001-01-03 A | 2004-06-18 | 38% | 559.78d? | 2001-01-03 | 2003-03-14 | 573d | 358d |  | S3 | 26984h | 9747.78h | SEC1 | Rel-6 | TSG | Maurice | Peter Howard, Vodafone | Peter.Howard@vodafone.com |  |  |
| 83 | 14.1 | **Enhanced HE control of security (including positive authentication reporting)** | 712d | 2001-01-03 A | 2003-09-25 | 23% | 545d | 2001-01-03 | 2003-03-14 | 573d | 549d |  | S3 | 14064h | 4008h |  | Rel-6 |  |  | Peter Howard, Vodafone | Peter.Howard@vodafone.com | 2026 |  |
| 84 | 14.1.1 | Stage 2 | 378d | 2001-01-03 | 2002-06-14 |  |  | 2001-01-03 | 2002-06-14 | 378d | 883d | finish no earlier than 2002-06-14 | S3 | 3024h |  |  | Rel-6 |  |  |  |  | 2027 |  |
| 85 | 14.1.3 | **Network domain security** | 334d | 2002-06-17 A | 2003-09-25 | 50% | 167d | 2002-06-17 | 2003-03-14 | 195d | 549d |  | S3 | 5344h | 2672h | SEC1-NDS | Rel-6 | TSG |  | Geir M. Køien, Telenor | Geir-myrdahl.koien@telenor.com |  | Sec |
| 86 | 14.1.3.1 | IP network layer security (NDS/IP) | 334d | 2002-06-17 A | 2003-09-25 | 50% | 167d | 2002-06-17 | 2003-03-14 | 195d | 549d | finish no earlier than 2003-09-25 | S3 | 2672h | 1336h | SEC1-NDS-IP | Rel-6 | WG |  |  |  |  |  |
| 87 | 12.2 | Network Domain Security; Authentication Framework (NDS/AF) | 521d? | 2002-02-15 A | 2004-02-13 | 70% | 156.3d? | 2002-02-15 | 2003-12-19 | 481d? | 448d | finish no earlier than 2004-02-13 | S3 | 4168h | 2917.6h | SEC1-NDS-AF | Rel-6 | TSG |  | Tommi Viitanen, Nokia | tommi.viitanen@nokia.com |  |  |
| 88 | 12.3 | Key Management of group keys for Voice Group Call Services | 191d | 2003-09-26 A | 2004-06-18 | 5% | 181.45d |  |  |  | 358d | finish no earlier than 2004-06-18 | S3 | 1528h | 76.4h | SECGKYV | Rel-6 | TSG | Maurice | Benno Tietz, Vodafone D2 | benno.tietz@vodafone.com |  |  |
| 89 | 16 | **IMS Phase 2** | 1112d? | 2000-08-28 A | 2004-11-30 | 57% | 474.02d? | 2000-08-28 | 2003-12-18 | 864d? | 241d |  | S1 | 119192h | 66213.2h | IMS2 | Rel-6 | TSG | Sang-Ui |  |  |  |  |
| 90 | 16.1 | Stage 2 of IMS Phase 2 | 275d | 2002-09-02 A | 2003-09-19 | 80% | 55d | 2002-09-02 | 2003-09-19 | 275d | 553d | finish no earlier than 2003-09-19 | S2 | 2200h | 1760h |  | Rel-6 |  |  |  |  |  |  |
| 91 | 13.2 | Enhancements to the Cx and Sh interfaces | 323d? | 2003-06-06 A | 2004-08-31 | 60% | 129.2d? | 2003-06-06 | 2003-12-12 | 136d? | 306d | finish no earlier than 2004-08-31 | N4 | 2584h | 1550.4h | IMS2-CCR | Rel-6 | WG |  |  |  |  |  |
| 92 | 16.12 | **IMS Group Management** | 650d? | 2002-03-14 A | 2004-09-08 | 55% | 293.27d? | 2002-03-14 | 2003-12-12 | 457d? | 300d |  | S1 | 11640h | 6388.26h | IMSGM | Rel-6 | TSG |  | Juha Kalliokulju (Nokia) | juha.kalliokulju@nokia.com |  |  |
| 93 | 16.12.1 | Stage 1 - TS on IMS group management | 193d | 2002-03-14 A | 2002-12-09 A | 100% |  | 2002-03-14 | 2002-12-09 | 193d |  | finish no earlier than 2002-12-09 | S1 | 1544h | 1544h |  | Rel-6 | TSG |  | Juha Kalliokulju (Nokia) | juha.kalliokulju@nokia.com |  |  |
| 94 | 13.3.2 | Stage 2 | 158d? | 2003-05-26 A | 2003-12-31 A | 100% |  | 2003-05-26 | 2003-09-23 | 87d? |  | finish no earlier than 2003-12-31 | S2 | 1264h | 1264h |  | Rel-6 |  |  |  |  |  |  |
| 95 | 13.3.3 | Stage 3 for IMS Group management (e.g. chat) | 454d? | 2002-12-13 A | 2004-09-08 | 20% | 363.2d? | 2002-12-13 | 2003-12-12 | 261d? | 300d | finish no earlier than 2004-09-08 | N1 | 3632h | 726.4h |  |  |  |  | Keith Drage, Lucent | drage@lucent.com |  |  |
| 96 | 13.4 | **IMS Conferencing** | 483d? | 2002-11-04 A | 2004-09-08 | 85% | 72.42d? | 2002-11-04 | 2003-12-12 | 290d? | 300d |  | N1 | 9920h | 8432.66h |  | Rel-6 |  |  |  |  |  |  |
| 97 | 13.4.1 | Stage 2 | 303d? | 2002-11-04 A | 2003-12-31 A | 100% |  | 2002-11-04 | 2003-09-26 | 235d? |  | finish no earlier than 2003-12-31 | S2 | 2424h | 2424h |  | Rel-6 |  |  |  |  |  |  |
| 98 | 13.4.2 | Stage 3 | 454d? | 2002-12-13 A | 2004-09-08 | 75% | 113.5d? | 2002-12-13 | 2003-12-12 | 261d? | 300d | finish no earlier than 2004-09-08 | N1 | 3632h | 2724h |  |  |  |  | Keith Drage, Lucent | drage@lucent.com |  |  |
| 99 | 16.11 | **IMS Messaging** | 650d? | 2002-03-14 A | 2004-09-08 | 73% | 175.72d? | 2002-03-14 | 2003-12-12 | 457d? | 300d |  | S1 | 15744h | 11487.9h | IMSM | Rel-6 | TSG |  | Juha Kalliokulju (Nokia) | juha.kalliokulju@nokia.com |  |  |
| 100 | 16.11.1 | TR on support of messaging in the IMS | 193d | 2002-03-14 A | 2002-12-09 A | 100% |  | 2002-03-14 | 2002-12-09 | 193d |  | finish no earlier than 2002-12-09 | S1 | 1544h | 1544h | IMSM-TR | Rel-6 | TSG |  | Juha Kalliokulju (Nokia) | juha.kalliokulju@nokia.com |  |  |
| 101 | 13.5.2 | Stage 1 22.340 | 23d? | 2002-11-11 A | 2002-12-11 A | 100% |  | 2002-11-11 | 2002-12-11 | 23d? |  | finish no earlier than 2002-12-11 | S1 | 184h | 184h | IMSM-TS | Rel-6 | TSG |  | Juha Kalliokulju (Nokia) | juha.kalliokulju@nokia.com |  |  |
| 102 | 13.5.3 | CRs to 22.140 & 22.228 | 263d? | 2002-03-14 A | 2003-03-17 A | 100% |  | 2002-03-14 | 2003-03-17 | 263d? |  | finish no earlier than 2003-03-17 | S1 | 2104h | 2104h | IMSM-CR | Rel-6 | TSG |  | Juha Kalliokulju (Nokia) | juha.kalliokulju@nokia.com |  |  |
| 103 | 16.11.3 | Stage 2 | 385d | 2002-11-04 A | 2004-04-23 | 90% | 38.5d | 2002-11-04 | 2003-09-26 | 235d | 398d | finish no earlier than 2004-04-23 | S2 | 3080h | 2772h |  | Rel-6 |  |  |  |  |  |  |
| 104 | 13.5.5 | Stage 3 for IMS Messaging | 454d? | 2002-12-13 A | 2004-09-08 | 30% | 317.8d? | 2002-12-13 | 2003-12-12 | 261d? | 300d | finish no earlier than 2004-09-08 | N1 | 3632h | 1089.6h |  |  |  |  | Keith Drage, Lucent | drage@lucent.com |  |  |

Notes:
- 78: This is a building block without particular end date
- 82: Added BB UE authentication and rapporteur added.
- 83: Added by P-000575 without any dates. 18/10/00: Change of WI title, added hyperlink rapporteur new end date 03/01. New end date and correct Release to be decided S3#18
- 84: New end date and correct Release to be decided S3#18
- 85: WID approved for Rel-6 at SA#17
- 86: Should be complete after SA3#27 / Text3: TS 33.210
- 87: WID approved SA#19. Work started after FS approved SA#18
- 88: Approved TSG#21 / Text3: 42.068, 43.068, 44.068, 42.069, 43.069, 44.069, 31.102, 24.008, 48.008, 42.009, 43.020
- 89: Not yet available: verbally approved at SA15, actual WID to be provided at SA16 by Lucent
- 91: 29/05/2003 CN4: New WID presented for approval at CN#20......... / 14/05/2004 CN4: Main open issues are version control and user profile.
- 101: Text3: 22.340
- 102: Text3: 22.140,22.228

| ID | WBS | Task | Duration | Start | Finish | Complete | Remaining | Baseline start | Baseline finish | Baseline duration | Total slack | Constraint | Resources | Work | Actual work | Text3 | Text6 | Text4 | Text5 | Text1 | Text2 | Text7 | Text9 | Text8 |
| --- | --- | --- | --- | --- | --- | --- | --- | --- | --- | --- | --- | --- | --- | --- | --- | --- | --- | --- | --- | --- | --- | --- | --- | --- |
| 105 | 16.7 | **IMS Local services** | 895d? | 2001-01-01 A | 2004-06-04 | 46% | 485.89d? | 2001-01-01 | 2003-12-12 | 770d? | 368d |  | S2 | 12848h | 5192.02h | 23.228 | Rel-6 |  |  |  |  |  |  |  |
| 106 | 16.7.1 | Stage 2 | 325d | 2001-01-01 A | 2002-03-29 A | 100% |  | 2001-01-01 | 2002-03-29 | 325d |  | start no earlier than 2001-01-01 | S2 | 2600h | 2600h |  | Rel-6 |  |  |  |  |  |  |  |
| 107 | 13.6.2 | Stage 3 for IMS Local services | 386d? | 2002-12-13 | 2004-06-04 |  |  | 2002-12-13 | 2003-12-12 | 261d? | 368d | finish no earlier than 2004-06-04 | N1 | 3088h |  |  |  | Keith Drage, Lucent | drage@lucent.com |  |  |  |  |  |
| 108 | 13.7 | **Additional SIP Capabilities support not covered by Rel-5** | 478d? | 2002-11-11 A | 2004-09-08 | 65% | 165.03d? | 2002-11-11 | 2003-12-12 | 285d? | 300d |  | N1 | 10136h | 6636.57h |  | Rel-6 |  |  |  |  |  |  |  |
| 109 | 13.7.1 | Stage 2 for add SIP cap (e.g. forking) | 335d? | 2002-11-11 A | 2004-02-20 A | 100% |  | 2002-11-11 | 2003-06-27 | 165d? |  | finish no earlier than 2004-02-20 | S2 | 2680h | 2680h |  | Rel-6 |  |  |  |  |  |  |  |
| 110 | 13.7.2 | Stage 3 for Additional SIP Capabilities | 454d? | 2002-12-13 A | 2004-09-08 | 40% | 272.4d? | 2002-12-13 | 2003-12-12 | 261d? | 300d | finish no earlier than 2004-09-08 | N1 | 3632h | 1452.8h |  |  | Keith Drage, Lucent | drage@lucent.com |  |  |  |  |  |
| 111 | 13.8 | Review additional SIP Capabilities against IMS | 326d? | 2002-12-13 A | 2004-03-12 | 20% | 260.8d? | 2002-12-13 | 2003-12-12 | 261d? | 428d | finish no earlier than 2004-03-12 | N1 | 2608h | 521.6h |  |  | Keith Drage, Lucent | drage@lucent.com |  |  |  |  |  |
| 112 | 16.5 | **Interworking between IMS and IP networks** | 1053d? | 2000-08-28 A | 2004-09-08 | 49% | 535.19d? | 2000-08-28 | 2003-12-12 | 860d | 300d |  | N3 | 28584h | 12033.6h | 23.821, 29.061, 29.162 | Rel-6 | Nigel Holland, BT | nigel.holland@bt.com | IMS-CCR-IWIP | BaAS | TSG | 2048 |  |
| 113 | 16.5.1 | Interworking for 3GPP_SIP and IETF_SIP | 730d | 2000-08-28 A | 2003-06-13 A | 100% |  | 2000-08-28 | 2003-12-12 | 860d |  | finish no earlier than 2003-06-13 | N3 | 5840h | 5840h | New TR 29.962 | Rel-6 | Thomas Belling, Siemens |  |  |  |  |  |  |
| 114 | 16.5.2 | Interworking for IPv6 to IPv4 | 860d | 2000-08-28 A | 2003-12-12 | 20% | 688d | 2000-08-28 | 2003-12-12 | 860d | 493d | finish no earlier than 2003-12-12 | N3 | 6880h | 1376h | 29.163 | Rel-6 |  |  |  |  |  |  |  |
| 115 | 13.9.3 | Interworking for IPv6 to IPv4 (SIP / SDP aspects) | 87d? | 2004-05-11 | 2004-09-08 |  |  |  |  |  | 300d | finish no earlier than 2004-09-08 | N1 | 696h |  |  | Rel-6 |  |  |  |  |  |  |  |
| 116 | 16.8.1 | stage 3 of interworking with non-IMS IP networks | 843d | 2001-03-14 A | 2004-06-04 | 40% | 505.8d | 2001-03-14 | 2003-12-12 | 718d | 368d | finish no earlier than 2004-06-04 | N1 | 6744h | 2697.6h |  | Rel-6 |  |  |  |  |  |  |  |
| 117 | 16.6.1 | Interworking between IMS and CS networks | 929d? | 2000-08-28 A | 2004-03-18 | 78% | 209d? | 2000-08-28 | 2003-09-05 | 790d? | 424d | finish no earlier than 2004-03-18 | N3 | 7432h | 5760h | 29.163, 29.061, 24.228, and new CN4 specification | Rel-6 | Brendan Mc Williams, Vodafone | brendan.mcwilliams@vf.vodafone.co.uk | IMS-CCR-IWCS | CCaR | TSG |  |  |
| 118 | 16.10 | Mn interface (IM-MGW to MGCF) enhancements (CN4 Part) | 418d | 2001-08-07 A | 2004-09-01 | 70% | 125.4d | 2002-09-02 | 2003-12-12 | 335d | 305d | finish no earlier than 2004-09-01 | N4 | 3344h | 2340.8h |  | Rel-6 |  |  | IMS-CCR-Mn |  |  |  |  |
| 119 | 13.12 | Mp (MRFC - MRFP) interface (CN4 Part) | 513d | 2002-12-13 | 2004-11-30 |  |  | 2002-10-07 | 2003-12-12 | 310d | 241d | finish no earlier than 2004-11-30 | N4 | 4104h |  |  | Rel-6 |  |  | IMS-CCR-Mp |  |  |  |  |
| 120 | 13.13 | Study of subscriber and operators relationship in IMS and related ISIM requirements for Rel 6” | 20d? | 2002-11-15 A | 2002-12-12 A | 100% |  | 2002-11-15 | 2002-12-12 | 20d? |  | finish no earlier than 2002-12-12 | S1 | 160h | 160h |  | Rel-6 | Juha Kalliokulju (Nokia) | juha.kalliokulju@nokia.com |  |  |  |  |  |
| 121 | 13.14 | Lawful Interception in the 3GPP Rel-6 architecture | 269d? | 2002-12-09 A | 2003-12-18 | 10% | 242.1d? | 2002-12-09 | 2003-12-18 | 269d? | 489d | finish no earlier than 2003-12-18 | S3 | 2152h | 215.2h | 33.106, 33.107, 33.108 | Rel-6 | Berthold Wilhelm | Berthold.Wilhelm@REGTP.DE | SEC1-LI |  | TSG |  |  |
| 122 | 13.15 | IMS Subscription and access scenarios | 130d? | 2002-12-16 A | 2003-06-13 A | 100% |  | 2002-12-16 | 2003-06-13 | 130d? |  | start no earlier than 2002-12-16 | S1 | 1040h | 1040h | 22.800 | Rel-6 |  |  |  |  |  |  |  |
| 123 | 14 | 3GPP Enablers for services like Push to Talk over Cellular (PoC) | 203d? | 2003-09-08 A | 2004-06-16 | 55% | 91.35d? |  |  |  | 360d | finish no earlier than 2004-06-16 | S2 | 1624h | 893.2h | 23.9xx | Rel-6 | Shabnam Sultana, Ericsson |  |  |  |  |  |  |
| 124 | 15 | Interworking aspects and migration scenarios for IPv4 based IMS Implementations (Study) | 210d? | 2003-09-08 A | 2004-06-25 | 55% | 94.5d? |  |  |  | 353d | finish no earlier than 2004-06-25 | S2 | 1680h | 924h |  | Rel-6 | Alexander Milinski, Siemens |  |  |  |  |  |  |
| 125 | 16.3 | **Interoperability and Commonality between IMS using different "IP-connectivity Networks"** | 325d? | 2002-09-16 A | 2003-12-12 | 99% | 0d? | 2002-09-16 | 2003-12-12 | 325d | 0d |  | S2 | 9176h | 6736h |  | Rel-6 |  |  | IMSCOOP |  | TSG |  | Sang-Ui |
| 126 | 16.3.1 | Stage 2 for Interoperability (no contributions assumed that no more will be done in 3GPP hence work may need to be done in pp2) | 272d | 2002-09-16 A | 2003-09-30 A | 100% |  | 2002-09-16 | 2003-09-19 | 265d |  | finish no earlier than 2003-09-30 | S2 | 2176h | 2176h |  | Rel-6 | Balazs Beternyi, Nokia |  |  |  |  |  |  |
| 127 | 16.2 | Stage 2 for commonality | 265d? | 2002-09-16 A | 2003-09-19 A | 100% |  | 2002-09-16 | 2003-09-19 | 265d? |  | start no earlier than 2002-09-16 | S2 | 2120h | 2120h |  | Rel-6 | Balazs Beternyi, Nokia |  |  |  |  |  |  |
| 128 | 16.3.2 | Stage 3 | 305d | 2002-10-14 A | 2003-12-12 A | 100% |  | 2002-10-14 | 2003-12-12 | 305d |  | finish no earlier than 2003-12-12 | N1 | 2440h | 2440h |  | Rel-6 | Keith Drage, Lucent | drage@lucent.com |  |  |  |  |  |

Notes:
- 112: [DAB 14.02.02] - end date pushed back to March 2003
- 113: [DAB - 20.08.03] - CN Part of TR Complete @ CN#20
- 117: [DAB - 23.05.03] - Remove ITU dependancies
- 118: [CN4] 17th May 2002, CN4; Will be handled in Rel-6...... / 14/05/2004 CN4: specification is agreed to sent to plenary for information
- 119: 27/11/2002 KK: WID approved at CN#18 (NP-020601)... / 14/05/2004 CN4: Work on the specification not started. it is an addition of Mn-Interface specification. Work will not be finish before CN#26

| ID | WBS | Task | Duration | Start | Finish | Complete | Remaining | Baseline start | Baseline finish | Baseline duration | Total slack | Constraint | Resources | Work | Actual work | Text1 | Text2 | Text4 | Text6 | Text7 | Text8 | Text9 | Text5 | Text3 |
| --- | --- | --- | --- | --- | --- | --- | --- | --- | --- | --- | --- | --- | --- | --- | --- | --- | --- | --- | --- | --- | --- | --- | --- | --- |
| 129 | 17 | **Support of Push Services** | 823d | 2001-01-03 A | 2004-02-27 | 98% | 19.49d | 2001-01-03 | 2003-12-26 | 778d | 438d |  | S1 | 11390.6h | 5608h | PUSH | CCaR | Yoshinori Kitada, NTT Comware | Rel-6 | TSG | Sang-Ui | 1365 |  |  |
| 130 | 17.1 | Stage 1 | 378d | 2001-01-03 A | 2002-06-14 A | 100% |  | 2001-01-03 | 2002-06-14 | 378d |  | finish no earlier than 2002-06-14 | S1 | 3024h | 3024h |  |  |  | Rel-6 |  |  |  |  |  |
| 131 | 17.3 | TR 23.976 on Push Architecture | 340d | 2002-11-11 A | 2004-02-27 | 95% | 17d | 2002-11-11 | 2003-12-26 | 295d | 438d | finish no earlier than 2004-02-27 | S2 | 2720h | 2584h |  |  | Nick Alfano, RIM | Rel-6 |  |  |  |  |  |
| 132 | 18 | **Multimedia Messaging (MMS) enhancements** | 803d? | 2002-08-15 A | 2005-09-12 | 47% | 424.05d? | 2002-08-15 | 2004-03-10 | 410d? | 37d |  | T2 | 26088h | 13519.6h | MMS6 | Mes | Josef Laumen, Siemens | Rel-6 | TSG | Friedhelm |  | Josef.Laumen@SAL.SIEMENS.DE |  |
| 133 | 18.1 | **Definition of service requirements** | 286d? | 2002-11-15 A | 2003-12-19 A | 100% |  | 2002-11-15 | 2003-12-20 | 286d? |  |  | S1 | 4576h | 4576h | MMS6-SR |  |  | Rel-6 |  |  |  |  | 22.140 |
| 134 | 18.1.1 | Definition of service requirements charging | 286d? | 2002-11-15 A | 2003-12-19 A | 100% |  | 2002-11-15 | 2003-12-20 | 286d? |  | finish no earlier than 2003-12-20 | S1 | 2288h | 2288h |  |  | Josef Laumen, Siemens | Rel-6 |  |  |  | Josef.Laumen@SAL.SIEMENS.DE | 22.140 |
| 135 | 18.2 | Technical realization | 542d | 2002-09-06 A | 2004-10-04 | 55% | 243.9d | 2002-08-15 | 2003-12-10 | 345d | 282d | finish no earlier than 2004-09-10 | T2 | 4336h | 2384.8h |  |  | Josef Laumen, Siemens | Rel-6 | TSG | Friedhelm |  | Josef.Laumen@SAL.SIEMENS.DE | 23.140 |
| 136 | 18.3 | OMA dependencies | 542d | 2003-08-15 A | 2005-09-12 | 15% | 460.7d | 2002-08-15 | 2004-03-10 | 410d | 37d | finish no earlier than 2004-09-10 | T2 | 4336h | 650.4h |  |  |  | Rel-6 | n/a | Friedhelm |  |  |  |
| 137 | 18.4 | MMS formats and codecs | 546d | 2002-08-15 A | 2004-09-16 | 60% | 218.4d | 2002-08-15 | 2003-12-18 | 351d | 294d | finish no earlier than 2004-09-16 | S4 | 4368h | 2620.8h | MMS6-Codec |  | Roberto Castagno (Nokia) | Rel-6 |  | Paolo |  | roberto.castagno@nokia.com | 26.140 |
| 138 | 18.5 | Check - Handling of private addressing schemes in MMS | 128d | 2003-12-10 A | 2004-06-04 | 20% | 102.4d |  |  |  | 368d | start no earlier than 2003-12-10 | T2 | 1024h | 204.8h |  |  | Matthias Röbke, T-Mobile | Rel-6 | TSG | Friedhelm |  | Matthias.Roebke@t-mobile.de | 23.140 |
| 139 | 18.6 | FS Multiple MMS Relay/Server Architecture | 128d | 2003-12-10 A | 2004-06-04 | 5% | 121.6d |  |  |  | 368d | start no earlier than 2003-12-10 | T2 | 1024h | 51.2h |  |  | Juan Gorospe, Telefónica Móviles | Rel-6 | TSG | Friedhelm |  | gorospe_j@tsm.es | new TR |
| 140 | 19 | **Rel-6 MExE enhancements** | 326d | 2002-03-08 A | 2003-06-06 A | 100% |  | 2002-03-08 | 2003-06-06 | 326d |  |  | T2 | 7328h | 7328h | MEXE6 | Ter |  | Rel-6 | TSG | Friedhelm |  |  |  |
| 141 | 19.1 | MExE Rel-6 Improvements and Investigations | 264d | 2002-03-08 A | 2003-03-12 A | 100% |  | 2002-03-08 | 2003-03-12 | 264d |  | finish no earlier than 2003-03-12 | T2 | 2112h | 2112h | MEXE6-ENHANC | Ter | Lars Brenk (TTPCom) | Rel-6 | TSG |  |  | lsb_ttpcom@HOTMAIL.COM | 22.057, 23.057 |
| 142 | 19.2 | MExE Run-Time Independent Framework Feasibility Study | 326d | 2002-03-08 A | 2003-06-06 A | 100% |  | 2002-03-08 | 2003-06-06 | 326d |  | finish no earlier than 2003-06-06 | T2 | 2608h | 2608h | MEXE6-RTIF | Ter | Aaron Cohen (Intel) | Rel-6 | TSG |  |  | Aaron.Cohen@intel.com | 22.857 |
| 143 | 21 | Subscription Management | 520d | 2002-09-20 A | 2004-09-16 | 75% | 130d | 2000-12-29 | 2004-03-19 | 841d | 294d | finish no earlier than 2004-09-16 | S5 | 4160h | 3120h | SuM |  | Istvan ABA (T-Mobile Austria) | Rel-6 | TSG | Adrian |  | istvan.aba@t-mobile.at | 32.140/1, 32.171/2 |
| 144 | 22 | **Support of Presence Capability** | 914d? | 2001-03-19 A | 2004-09-16 | 58% | 386.84d? | 2001-03-19 | 2003-12-19 | 720d? | 294d |  | S1 | 27248h | 15715.7h | PRESNC |  | Mark Cataldo, Motorola | Rel-6 | TSG | Michael | 11004 |  |  |
| 145 | 22.1 | Stage 1 | 610d | 2001-03-19 A | 2003-07-18 A | 100% |  | 2001-03-19 | 2003-07-18 | 610d |  | finish no earlier than 2003-07-18 | S1 | 4880h | 4880h |  |  |  | Rel-6 |  |  | 11005 |  |  |
| 146 | 22.2 | Stage 2 | 268d | 2001-09-12 A | 2002-09-20 A | 100% |  | 2001-09-12 | 2002-09-20 | 268d |  | finish no earlier than 2002-09-20 | S2 | 2144h | 2144h |  |  |  | Rel-6 | TSG |  |  |  |  |
| 147 | 22.3 | Stage 3 | 638d | 2002-04-01 A | 2004-09-08 | 80% | 127.6d | 2002-04-01 | 2003-12-19 | 450d | 300d | finish no earlier than 2004-09-08 | N1 | 5104h | 4083.2h |  |  | Keith Drage, Lucent | Rel-6 |  |  |  | drage@lucent.com |  |
| 148 | 21.4 | Media Codecs and Formats for IMS Messaging and Presence | 331d? | 2003-06-12 A | 2004-09-16 | 10% | 297.9d? | 2003-06-12 | 2003-12-18 | 136d? | 294d | finish no earlier than 2004-09-16 | S4 | 2648h | 264.8h | PRESNC-COFIMP |  | Harri Honko (Nokia) | Rel-6 | TSG | Paolo |  | harri.honko@nokia.com | TS 26.141 |
| 149 | 22.4 | Security issues | 79d | 2002-08-26 A | 2002-12-12 | 20% | 63.2d | 2002-08-26 | 2002-12-12 | 79d | 754d | finish no earlier than 2002-12-12 | S3 | 632h | 126.4h |  |  |  | Rel-6 |  |  |  |  |  |
| 150 | 22.5 | USIM issues | 79d | 2002-03-04 | 2002-06-20 |  |  | 2002-03-04 | 2002-06-20 | 79d | 879d | start no earlier than 2002-03-04 | T3 | 632h |  |  |  |  | Rel-6 |  |  |  |  |  |
| 151 | 21.7 | TR on Presence and Availability Management | 487d | 2002-10-31 | 2004-09-10 |  |  |  |  |  | 298d | finish no earlier than 2004-09-10 | N5 | 3896h |  |  |  | Chelo ABARCA (Alcatel) | Rel-6 | TSG | Adrian |  | Chelo.Abarca@alcatel.fr | 29.998-14 |
| 152 | 25 | **Enhanced A/Gb feasibility study** | 51d? | 2002-08-30 A | 2002-11-08 | 75% | 12.75d? | 2002-08-30 | 2002-11-08 | 51d? | 778d |  | GP | 4080h | 3162h | AGbEnFS |  | J-L Carrizo, Vodafone | Rel-6 | TSG | Paolo |  | jose-luis.carrizo@vodafone.co.uk |  |
| 153 | 25.1 | **Feasibility study on A/Gb enhancements** | 51d? | 2002-08-30 A | 2002-11-08 | 75% | 12.75d? | 2002-08-30 | 2002-11-08 | 51d? | 778d |  | G2 | 3672h | 2856h | AGbEnFS-FS |  |  | Rel-6 | TSG |  |  |  |  |
| 154 | 25.1.1 | Requirements for the support of conversational services | 51d | 2002-08-30 A | 2002-11-08 A | 100% |  | 2002-08-30 | 2002-11-08 | 51d |  | finish no earlier than 2002-11-08 | GP | 408h | 408h |  |  |  | Rel-6 |  |  |  |  |  |
| 155 | 22.1.2 | Identification of the different building blocks for the provision of conversational services on the existing A/Gb protocol stack | 51d? | 2002-08-30 A | 2002-11-08 A | 100% |  | 2002-08-30 | 2002-11-08 | 51d? |  | finish no earlier than 2002-11-08 | GP | 408h | 408h |  |  |  | Rel-6 |  |  |  |  |  |
| 156 | 22.1.3 | Outline of impact and feasibility of these building blocks and their different solutions | 51d? | 2002-08-30 A | 2002-11-08 A | 100% |  | 2002-08-30 | 2002-11-08 | 51d? |  | finish no earlier than 2002-11-08 | GP | 408h | 408h |  |  |  | Rel-6 |  |  |  |  |  |
| 157 | 25.1.2 | Identification of the different building blocks for the provision of conversational services on the existing A/Gb protocol stack | 51d | 2002-08-30 | 2002-11-08 |  |  | 2002-08-30 | 2002-11-08 | 51d | 778d | finish no earlier than 2002-11-08 | G2 | 408h |  |  |  |  | Rel-6 |  |  |  |  |  |
| 158 | 25.1.3 | Outline of impact and feasibility of these building blocks and their different solutions | 51d | 2002-08-30 | 2002-11-08 |  |  | 2002-08-30 | 2002-11-08 | 51d | 778d | finish no earlier than 2002-11-08 | G2 | 408h |  |  |  |  | Rel-6 |  |  |  |  |  |
| 159 | 25.1.4 | Impact on 3GPP architecture and requirement to co-ordinatge with other TSGs (CN, SA) | 51d | 2002-08-30 A | 2002-11-08 A | 100% |  | 2002-08-30 | 2002-11-08 | 51d |  | finish no earlier than 2002-11-08 | GP | 408h | 408h |  |  |  | Rel-6 |  |  |  |  |  |
| 160 | 25.1.5 | Standardisation effort | 51d | 2002-08-30 A | 2002-11-08 A | 100% |  | 2002-08-30 | 2002-11-08 | 51d |  | finish no earlier than 2002-11-08 | GP | 408h | 408h |  |  |  | Rel-6 |  |  |  |  |  |
| 161 | 25.1.6 | Dependency to other features | 51d | 2002-08-30 A | 2002-11-08 A | 100% |  | 2002-08-30 | 2002-11-08 | 51d |  | finish no earlier than 2002-11-08 | GP | 408h | 408h |  |  |  | Rel-6 |  |  |  |  |  |

Notes:
- 129: AS: Changed from FS to actual support of Push
- 144: A Sultan merged "Presence Service Enhancements" (UID31028, PRES1) to this feature as no answer was provided on why Presence and Presence Encmts had same target completion date
- 148: Also for 31022 IMS Messaging
- 149: LSs handled in SA3. WID approved SA#17 Contribution at S3#25 & following e-mail discussion.
- 151: CN#23: Moved from OSA3 to PRESNC
- 152: Closed

| ID | WBS | Task | Duration | Start | Finish | Complete | Remaining | Baseline start | Baseline finish | Baseline duration | Total slack | Constraint | Resources | Work | Actual work | Text1 | Text4 | Text5 | Text6 | Text7 | Text8 | Text3 | Text9 |
| --- | --- | --- | --- | --- | --- | --- | --- | --- | --- | --- | --- | --- | --- | --- | --- | --- | --- | --- | --- | --- | --- | --- | --- |
| 162 | 26 | **Flexible Layer One for GERAN** | 1170d | 2000-01-03 A | 2004-06-25 | 86% | 157.96d | 2000-01-03 | 2003-11-21 | 1015d | 353d |  | GP | 75303h | 49540.5h | FLOGER | Benoist Sébire | benoist.sebire@nokia.com | Rel-6 | TSG | Paolo |  |  |
| 163 | 26.1 | **Realisation of a Flexible Layer One** | 1125d | 2000-01-03 A | 2004-04-23 | 91% | 99.96d | 2000-01-03 | 2003-06-27 | 910d | 398d |  | GP | 42808h | 33716h | FLOGER-Real | Benoist Sébire | benoist.sebire@nokia.com | Rel-6 |  |  |  |  |
| 164 | 26.1.1 | Technical Report | 471d | 2002-04-19 A | 2004-02-06 A | 100% |  | 2002-04-19 | 2003-06-27 | 311d |  | finish no earlier than 2004-02-06 | GP | 3768h | 3768h |  |  |  | Rel-6 |  |  |  |  |
| 165 | 26.1.2 | Architecture in 45.001 and 43.051 | 526d | 2002-04-19 A | 2004-04-23 | 90% | 52.6d | 2002-04-19 | 2003-06-27 | 311d | 398d | finish no earlier than 2004-04-23 | G1 | 4208h | 3787.2h |  |  |  | Rel-6 |  |  |  |  |
| 166 | 26.1.3 | Multiplexing in 45.002 | 526d | 2002-04-19 A | 2004-04-23 | 90% | 52.6d | 2002-04-19 | 2003-06-27 | 311d | 398d | finish no earlier than 2004-04-23 | G1 | 4208h | 3787.2h |  |  |  | Rel-6 |  |  |  |  |
| 167 | 26.1.4 | Channel Coding in 45.003 | 526d | 2002-04-19 A | 2004-04-23 | 90% | 52.6d | 2002-04-19 | 2003-06-27 | 311d | 398d | finish no earlier than 2004-04-23 | G1 | 4208h | 3787.2h |  |  |  | Rel-6 |  |  |  |  |
| 168 | 26.1.5 | Performance Requirements in 45.005 | 1125d | 2000-01-03 A | 2004-04-23 | 90% | 112.5d | 2000-01-03 | 2003-06-27 | 910d | 398d | finish no earlier than 2004-04-23 | G1 | 9000h | 8100h |  |  |  | Rel-6 |  |  |  |  |
| 169 | 26.1.6 | Radio subsystem link control in 45.008 | 526d | 2002-04-19 A | 2004-04-23 | 90% | 52.6d | 2002-04-19 | 2003-06-27 | 311d | 398d | finish no earlier than 2004-04-23 | G1 | 4208h | 3787.2h |  |  |  | Rel-6 |  |  |  |  |
| 170 | 26.1.7 | Requirements in 44.004 | 526d | 2002-04-19 A | 2004-04-23 | 90% | 52.6d | 2002-04-19 | 2003-06-27 | 311d | 398d | finish no earlier than 2004-04-23 | G2 | 4208h | 3787.2h |  |  |  | Rel-6 |  |  |  |  |
| 171 | 26.2 | **Signalling and protocol support for a Flexible Layer One** | 526d | 2002-04-19 A | 2004-04-23 | 80% | 105.2d | 2002-04-19 | 2003-06-27 | 311d | 398d |  | G2 | 12624h | 7731.2h | FLOGER-SigPro | Benoist Sébire | benoist.sebire@nokia.com | Rel-6 |  |  |  |  |
| 172 | 26.2.1 | Modifications to RLC/MAC in 44.060 and 44.160 | 526d | 2002-04-19 A | 2004-04-23 | 80% | 105.2d | 2002-04-19 | 2003-06-27 | 311d | 398d | finish no earlier than 2004-04-23 | G2 | 4208h | 3366.4h |  |  |  | Rel-6 |  |  |  |  |
| 173 | 26.2.2 | Modifications to RRC in 44.118 and 44.018 | 526d | 2002-04-19 A | 2004-04-23 | 80% | 105.2d | 2002-04-19 | 2003-06-27 | 311d | 398d | finish no earlier than 2004-04-23 | G2 | 4208h | 3366.4h |  |  |  | Rel-6 |  |  |  |  |
| 174 | 26.3 | **Security for a Flexible Layer One** | 356d | 2002-04-19 A | 2003-08-29 A | 100% |  | 2002-04-19 | 2003-06-27 | 311d |  |  | S3, G2 | 5663.04h | 5663.04h | FLOGER-SecFLO | Benoist Sébire | benoist.sebire@nokia.com | Rel-6 |  |  |  |  |
| 175 | 26.3.1 | Ciphering in 44.160,44.118, 44.060 and 44.018 | 356d | 2002-04-19 A | 2003-08-29 A | 100% |  | 2002-04-19 | 2003-06-27 | 311d |  | finish no earlier than 2003-08-29 | S3, G2 | 2848h | 2848h |  |  |  | Rel-6 |  |  |  |  |
| 176 | 26.4 | **GERAN MS Conformance test for the Flexible Layer One** | 101d | 2004-02-06 | 2004-06-25 |  |  | 2002-11-22 | 2003-11-21 | 260.5d | 353d |  | G4; G5 | 3232h |  | FLOGER-Msconf | Benoist Sébire | benoist.sebire@nokia.com | Rel-6 |  |  |  |  |
| 177 | 26.4.1 | MS Test in 51.01050085 | 101d | 2004-02-06 | 2004-06-25 |  |  | 2002-11-22 | 2003-11-21 | 260.5d | 353d | start no earlier than 2004-02-06 | G4; G5 | 1616h |  |  |  |  | Rel-6 |  |  |  |  |
| 178 | 26.5 | **GERAN BTS Conformance test for the Flexible Layer One** | 101d | 2004-02-06 | 2004-06-25 |  |  | 2002-04-19 | 2003-11-21 | 416d | 353d |  | G3 | 1616h |  | FLOGER-BTSconf | Benoist Sébire | benoist.sebire@nokia.com | Rel-6 |  |  |  |  |
| 179 | 26.5.1 | BTS Test in 51.021 | 101d | 2004-02-06 | 2004-06-25 |  |  | 2002-04-19 | 2003-11-21 | 416d | 353d | start no earlier than 2004-02-06 | G3 | 808h |  |  |  |  | Rel-6 |  |  |  |  |
| 180 | 27 | Uplink TDOA feasibility study | 151d | 2001-11-30 A | 2002-06-28 A | 100% |  | 2001-11-30 | 2002-06-28 | 151d |  | finish no earlier than 2002-06-28 | GP | 1208h | 1208h | TDOAF | Bob Gross, TruePosition, Inc. | rlgross@trueposition.com | Rel-6 |  | Paolo | 45.811 |  |
| 181 | 28 | **Multimedia Broadcast and Multicast Service** | 940d? | 2001-05-11 A | 2004-12-16 | 37% | 595.57d? | 2001-05-11 | 2004-03-19 | 746d | 229d |  | S1 | 99969.6h | 32844.6h | MBMS |  |  | Rel-6 | TSG | Michael |  |  |
| 182 | 28.1 | Stage 1 | 232d | 2001-05-11 A | 2002-04-01 A | 100% |  | 2001-05-11 | 2002-04-01 | 232d |  | finish no earlier than 2002-04-01 | S1 | 1856h | 1856h |  |  |  | Rel-6 |  |  | 22.146, 22.101 | 11003 |
| 183 | 28.2 | **Stage 2** | 648d | 2001-09-24 A | 2004-03-17 | 99% | 0d | 2001-09-24 | 2003-09-19 | 520d | 0d |  | S2 | 10408h | 6548.8h |  |  |  | Rel-6 | TSG |  |  |  |
| 184 | 28.2.1 | TR on Architectural Study | 240d | 2001-09-24 A | 2002-08-23 A | 100% |  | 2001-09-24 | 2002-08-23 | 240d |  | finish no earlier than 2002-08-23 | S2 | 1920h | 1920h |  |  |  | Rel-6 |  |  |  |  |
| 185 | 28.2.2 | Stage 2 Specification Work. (User Service aspects may impact) (progress will be check in Friday of S2 #38 !!) | 413d | 2002-08-19 A | 2004-03-17 A | 100% |  | 2002-08-19 | 2003-09-19 | 285d |  | finish no earlier than 2004-03-17 | S2 | 3304h | 3304h |  |  |  | Rel-6 |  |  |  |  |
| 186 | 28.3 | Introduction of MBMS in RAN | 707d | 2002-01-01 A | 2004-09-15 | 80% | 141.4d | 2002-01-01 | 2004-03-19 | 579d | 295d | finish no earlier than 2004-09-15 | R2 | 5656h | 4524.8h | MBMS-RAN | Juho Pirskanen , Nokia | juho.pirskanen@nokia.com | Rel-6 | TSG | MCC_RAN |  | 2481 |
| 187 | 28.4 | Support of the MBMS in CN protocols | 582d | 2002-06-18 A | 2004-09-08 | 60% | 232.8d | 2002-06-18 | 2003-12-12 | 389d | 300d | finish no earlier than 2004-09-08 | N1 | 4656h | 2793.6h |  |  |  | Rel-6 | TSG |  |  |  |
| 188 | 25.5 | Gmb interface for MBMS (CN3 part) | 211d | 2003-08-29 A | 2004-06-18 | 10% | 189.9d |  |  |  | 358d | finish no earlier than 2004-06-18 | N3 | 1688h | 168.8h |  |  |  | Rel-6 |  |  |  |  |
| 189 | 28.5 | Security Aspects of Multimedia Broadcast/Multicast Service (MBMS) | 324d | 2002-07-01 A | 2003-09-25 | 20% | 259.2d | 2002-07-01 | 2003-02-28 | 175d | 549d | finish no earlier than 2003-09-25 | S3 | 2592h | 518.4h | MBMS | Escott, Adrian, 3 | adrian.escott@three.co.uk | Rel-6 | TSG |  |  |  |

Notes:
- 162: Nokia, Ericsson, Siemens, Telia
- 163: Started
- 171: Started
- 174: Started
- 176: Not started
- 178: Not started
- 181: Title renamed at SA#13
- 182: This may or may not be a separate stage 1. In the meantime, CRs are proposed for 22.101
- 189: WID approved SA#17

| ID | WBS | Task | Duration | Start | Finish | Complete | Remaining | Baseline start | Baseline finish | Baseline duration | Total slack | Constraint | Resources | Work | Actual work | Text1 | Text6 | Text7 | Text3 | Text8 | Text9 | Text4 | Text5 |
| --- | --- | --- | --- | --- | --- | --- | --- | --- | --- | --- | --- | --- | --- | --- | --- | --- | --- | --- | --- | --- | --- | --- | --- |
| 190 | 28.6 | **Support of MBMS in GERAN** | 737d? | 2001-08-30 A | 2004-06-25 | 21% | 579.78d? | 2002-08-30 | 2003-11-21 | 321d | 353d |  | GP | 53328h | 10749.5h | MBMS-GERAN | Rel-6 | TSG |  |  |  |  |  |
| 191 | 28.6.1 | Impact on the logical and physical channels | 476d | 2002-08-30 A | 2004-06-25 | 25% | 357d | 2002-08-30 | 2003-11-21 | 321d | 353d | finish no earlier than 2004-06-25 | GP | 3808h | 952h |  | Rel-6 |  |  |  |  |  |  |
| 192 | 28.6.4 | Re-synchronisation at cell change | 216d | 2002-08-30 | 2003-06-27 |  |  | 2002-08-30 | 2003-06-27 | 216d | 613d | finish no earlier than 2003-06-27 | G2 | 1728h |  |  | Rel-6 |  |  |  |  |  |  |
| 193 | 25.7.3 | Simultaneous support of MBMS services | 476d? | 2002-08-30 A | 2004-06-25 | 25% | 357d? |  |  |  | 353d | finish no earlier than 2004-06-25 | GP | 3808h | 952h |  | Rel-6 |  |  |  |  |  |  |
| 194 | 25.7.4 | Simultaneous support of MBMS and non-MBMS services | 737d? | 2001-08-30 A | 2004-06-25 | 25% | 552.75d? |  |  |  | 353d | finish no earlier than 2004-06-25 | GP | 5896h | 1474h |  | Rel-6 |  |  |  |  |  |  |
| 195 | 25.7.5 | Resynchronisation at cell change | 737d? | 2001-08-30 A | 2004-06-25 | 25% | 552.75d? |  |  |  | 353d | start no earlier than 2001-08-30 | GP | 5896h | 1474h |  | Rel-6 |  |  |  |  |  |  |
| 196 | 28.6.5 | Decision making process between point-to-point or pont-to-multipoint configurations | 476d | 2002-08-30 A | 2004-06-25 | 25% | 357d | 2002-08-30 | 2003-11-21 | 321d | 353d | finish no earlier than 2004-06-25 | GP | 3808h | 952h |  | Rel-6 |  |  |  |  |  |  |
| 197 | 28.6.6 | MBMS channel allocations procedures to multiple MSs | 476d | 2002-08-30 A | 2004-06-25 | 25% | 357d | 2002-08-30 | 2003-11-21 | 321d | 353d | finish no earlier than 2004-06-25 | GP | 3808h | 952h |  | Rel-6 |  |  |  |  |  |  |
| 198 | 28.6.7 | Changes to the Gb interface | 476d | 2002-08-30 A | 2004-06-25 | 25% | 357d | 2002-08-30 | 2003-11-21 | 321d | 353d | finish no earlier than 2004-06-25 | GP | 3808h | 952h |  | Rel-6 |  |  |  |  |  |  |
| 199 | 28.6.8 | GERAN specific changes to the Iu-ps interface | 476d | 2002-08-30 A | 2004-06-25 | 25% | 357d | 2002-08-30 | 2003-11-21 | 321d | 353d | finish no earlier than 2004-06-25 | GP | 3808h | 952h |  | Rel-6 |  |  |  |  |  |  |
| 200 | 28.6.9 | Interaction between MBMS and Iu-flex | 476d | 2002-08-30 A | 2004-06-25 | 25% | 357d | 2002-08-30 | 2003-11-21 | 321d | 353d | finish no earlier than 2004-06-25 | GP | 3808h | 952h |  | Rel-6 |  |  |  |  |  |  |
| 201 | 28.6.10 | Security aspects | 476d | 2002-08-30 A | 2004-06-25 | 25% | 357d | 2002-08-30 | 2003-11-21 | 321d | 353d | finish no earlier than 2004-06-25 | GP | 3808h | 952h |  | Rel-6 |  |  |  |  |  |  |
| 202 | 25.7.12 | MS conformance tests- G3 | 476d? | 2002-08-30 | 2004-06-25 |  |  |  |  |  | 353d | start no earlier than 2002-08-30 | G3 | 3808h |  |  | Rel-6 |  |  |  |  |  |  |
| 203 | 28.6.11 | MS conformance tests - G5 | 216d | 2002-08-30 | 2003-06-27 |  |  | 2002-08-30 | 2003-06-27 | 216d | 613d | finish no earlier than 2003-06-27 | G5 | 1728h |  |  | Rel-6 |  |  |  |  |  |  |
| 204 | 28.1 | **MBMS User Services** | 940d? | 2001-05-11 A | 2004-12-16 | 45% | 514.01d? | 2001-05-11 | 2002-04-01 | 232d | 229d |  | S1 | 12544h | 5684.75h |  | Rel-6 |  | 22.246 | Michael | 11003 |  |  |
| 205 | 28.1 | MBMS User Services Stage 1 | 232d | 2001-05-11 A | 2002-04-01 | 80% | 46.4d | 2001-05-11 | 2002-04-01 | 232d | 937d | finish no earlier than 2002-04-01 | S1 | 1856h | 1484.8h |  | Rel-6 |  | 22.246 | Michael | 11003 |  |  |
| 206 | 25.8.2 | Definition of MBMS user services, media codecs, formats and transport/application protocols using MBMS | 396d? | 2003-06-12 A | 2004-12-16 | 25% | 297d? | 2003-06-12 | 2004-03-18 | 201d? | 229d | finish no earlier than 2004-12-16 | S4 | 3168h | 792h | MBMS-TSMBMS | Rel-6 | TSG | 26.346 | Paolo |  | Igor Curcio (Nokia) | igor.curcio@nokia.com |
| 207 | 29 | **Speech Recognition and Speech Enabled Services** | 699d? | 2001-10-08 A | 2004-06-10 | 94% | 39.82d? | 2001-10-08 | 2003-12-09 | 567d? | 364d |  | S1 | 11672h | 11007h | SRSES | Rel-6 | TSG |  | Michael |  |  |  |
| 208 | 29.1 | Speech Enabled Services Based on Distributed Speech Recognition (DSR) | 115d | 2001-10-08 A | 2002-03-15 A | 100% |  | 2001-10-08 | 2002-03-15 | 115d |  | finish no earlier than 2002-03-15 | S1 | 920h | 920h | DSR | Rel-6 | TSG | 22.941, 23.207, 22.243 |  |  | D Williams, QUALCOMM, Inc. | Dwilliams@qualcomm.com |
| 209 | 29.2 | TR on Architectural impacts | 212d | 2003-05-12 A | 2004-03-02 A | 100% |  | 2003-05-12 | 2003-12-09 | 152d |  | finish no earlier than 2004-03-02 | S2 | 1696h | 1696h |  | Rel-6 |  |  |  |  |  |  |
| 210 | 26.3 | Codec Work to Support Speech Recognition Framework for Automated Voice Services | 433d? | 2002-10-15 A | 2004-06-10 | 90% | 43.3d? | 2002-10-15 | 2003-09-26 | 249d? | 364d | finish no earlier than 2004-06-10 | S4 | 3464h | 3117.6h | SRSES-Codec | Rel-6 | WG | 26.235, 26.236, 26.243 | Paolo |  | David Pearce, Motorola | bdp003@motorola.com |
| 211 | 30 | **Generic User Profile** | 1063d | 2001-10-08 A | 2005-11-02 | 70% | 320.56d | 2001-10-08 | 2003-12-12 | 570d | 0d |  | S1 | 31583.8h | 22059.5h | GUP | Rel-6 | TSG |  | Michael |  |  |  |
| 212 | 30.1 | Stage 1 - Requirements | 430d | 2001-10-08 A | 2003-05-30 A | 100% |  | 2001-10-08 | 2003-05-30 | 430d |  | finish no earlier than 2002-12-09 | S1 | 3440h | 3440h |  | Rel-6 |  | 22.240, 22.228 |  |  | Paul Amery (Orange) | paul.amery@orange.co.uk |
| 213 | 30.3 | Stage 2 - Architecture | 355d | 2002-01-28 A | 2003-06-06 A | 100% |  | 2002-01-28 | 2003-06-06 | 355d |  | finish no earlier than 2003-06-06 | S2 | 2840h | 2840h |  | Rel-6 |  | 23.240 |  |  | Nacho Uzquiano (Telefonica) | uzquiano_ji@tsm.es |
| 214 | 30.2 | Stage 2 - Data Description Method | 630d | 2002-12-05 A | 2005-05-04 | 90% | 63d | 2001-10-08 | 2003-12-10 | 568d | 130d | finish no earlier than 2004-03-05 | T2 | 5040h | 4536h |  | Rel-6 | TSG | 23.241 | Friedhelm |  | Kurt Bischinger (T-Mobile AUSTRIA) | kurt.bischinger@t-mobile.at |
| 215 | 30.4 | Stage 3 - Common objects | 760d | 2002-12-05 A | 2005-11-02 | 60% | 304d | 2001-10-08 | 2003-12-10 | 568d | 0d | finish no earlier than 2004-09-03 | T2 | 6080h | 3648h |  | Rel-6 | TSG | 24.241 | Friedhelm |  |  |  |
| 216 | 30.5 | Stage 3 - Network | 401.98d | 2003-05-19 A | 2004-11-30 | 40% | 241.19d | 2003-05-19 | 2003-12-12 | 149.98d | 241d | finish no earlier than 2004-11-30 | N4 | 3215.84h | 1286.34h |  | Rel-6 |  | 29.240 |  |  |  |  |
| 217 | 30.6 | Security Aspects | 308d | 2002-07-16 A | 2003-09-18 | 15% | 261.8d | 2002-07-16 | 2003-09-18 | 308d | 554d | finish no earlier than 2003-09-18 | S3 | 2464h | 369.6h |  | Rel-6 | WG | 33.102, 33.203, 33.210 |  |  | Owen, Bradley | bvowen@lucent.com |

Notes:
- 216: 17 May no activity in CN4...... / 14/05/2004 CN4: GUP will not be finish before CN#26
- 217: WID approved SA#17. SA WG3 progress slow, depends on progress in other groups.

| ID | WBS | Task | Duration | Start | Finish | Complete | Remaining | Baseline start | Baseline finish | Baseline duration | Total slack | Constraint | Resources | Work | Actual work | Text1 | Text6 | Text7 | Text8 | Text4 | Text5 | Text3 | Text9 | Text10 | Text11 | Text12 |
| --- | --- | --- | --- | --- | --- | --- | --- | --- | --- | --- | --- | --- | --- | --- | --- | --- | --- | --- | --- | --- | --- | --- | --- | --- | --- | --- |
| 218 | 31 | **Digital Rights Management** | 380d? | 2001-10-08 A | 2003-03-21 | 55% | 172.17d? | 2001-10-08 | 2003-03-21 | 380d? | 683d |  | S1 | 7200h | 3937.84h | DRM | Rel-6 | TSG | Michael |  |  |  |  |  |  |  |
| 219 | 31.1 | Requirements | 179d | 2001-10-08 A | 2002-06-13 A | 100% |  | 2001-10-08 | 2002-06-13 | 179d |  | finish no earlier than 2002-06-13 | S1 | 1432h | 1432h |  | Rel-6 |  |  | Nicholas Wood, Openwave Systems | nicholas.wood@openwave.com |  |  |  |  |  |
| 220 | 28.2 | Monitoring of Stages 2 and 3 progress (actual work to be done by OMA) | 155d? | 2002-08-19 A | 2003-03-21 | 20% | 124d? | 2002-08-19 | 2003-03-21 | 155d? | 683d | start no earlier than 2002-08-19 | S1 | 1240h | 248h |  | Rel-6 |  |  |  |  |  |  |  |  |  |
| 221 | 31.3 | Monitoring of Security (work done by OMA) | 186d | 2002-06-17 A | 2003-03-03 | 40% | 111.6d | 2002-06-17 | 2003-03-03 | 186d | 697d | finish no earlier than 2003-03-03 | S3 | 1488h | 595.2h |  | Rel-6 |  |  |  |  |  |  |  |  |  |
| 222 | 32 | **WLAN-UMTS Interworking** | 1282d? | 2000-01-03 A | 2004-11-30 | 89% | 145.35d? | 2000-01-03 | 2003-12-12 | 1030d? | 241d |  | S1 | 35048h | 31074.4h | WLAN | Rel-6 | TSG | Michael | Fredric Paint, Telenor | frederic.paint@telenor.com |  |  |  |  |  |
| 223 | 32.1 | Technical Report | 900d? | 2000-01-03 A | 2003-06-13 | 99% | 9d? | 2000-01-03 | 2003-06-13 | 900d? | 623d | finish no earlier than 2003-06-13 | S1 | 7200h | 7128h | WLAN-TR | Rel-6 |  |  | Fredric Paint, Telenor | frederic.paint@telenor.com | 22.934, 22.101, 22.105 |  |  |  |  |
| 224 | 29.2 | CRs to implement WLAN | 900d? | 2000-01-03 A | 2003-06-13 | 99% | 9d? | 2000-01-03 | 2003-06-13 | 900d? | 623d | finish no earlier than 2003-06-13 | S1 | 7200h | 7128h | WLAN-CR | Rel-6 |  |  | Fredric Paint, Telenor | frederic.paint@telenor.com | 22.934, 22.101, 22.105, 22.115 |  |  |  |  |
| 225 | 32.2 | Architecture Definition (scenarii 2 & 3 done) | 505d | 2002-03-25 A | 2004-02-27 | 95% | 25.25d | 2002-03-25 | 2003-09-26 | 395d | 438d | finish no earlier than 2004-02-27 | S2 | 4040h | 3838h |  | Rel-6 | TSG |  |  |  |  |  |  |  |  |
| 226 | 32.3 | Security | 125d | 2002-09-30 A | 2003-03-21 | 30% | 87.5d | 2002-09-30 | 2003-03-21 | 125d | 683d | finish no earlier than 2003-03-21 | S3 | 1000h | 300h |  | Rel-6 | TSG |  | Lopez-Soria, Luis, Ericsson | luis.lopez-soria@ece.ericsson.se | 21.133, 33.106, 33.107, 33.108, 33.200, 33.203, 33.210 |  |  |  |  |
| 227 | 29.5 | Stage 3 - CN4 aspects | 398d? | 2003-05-23 A | 2004-11-30 | 65% | 139.3d? | 2003-05-23 | 2003-12-12 | 146d? | 241d | finish no earlier than 2004-11-30 | N4 | 3184h | 2069.6h | WLAN-IW | Rel-6 | TSG |  | Rodriguez ,Raquel, Nokia | raquel.rodriguez@nokia.com | 29.234, 29.061 |  |  |  |  |
| 228 | 29.6 | WLAN interworking- stage 3 | 271d? | 2003-05-23 A | 2004-06-04 | 70% | 81.3d? | 2003-05-23 | 2003-12-12 | 146d? | 368d | finish no earlier than 2004-06-04 | N1 | 2168h | 1517.6h |  | Rel-6 | WG |  |  |  |  |  |  |  |  |
| 229 | 33 | **Priority Service** | 347d? | 2002-05-30 A | 2003-09-26 | 67% | 116.04d? | 2002-05-30 | 2003-09-26 | 347d? | 548d |  | S1 | 7512h | 4999.9h | PRIOR | Rel-6 | TSG | Michael |  |  |  |  |  |  |  |
| 230 | 33.1 | Feasibility Study | 1d | 2002-06-14 A | 2002-06-14 A | 100% |  | 2002-06-14 | 2002-06-14 | 1d |  | finish no earlier than 2002-06-14 | S1 | 8h | 8h | PRIOR-FS | Rel-6 |  | Michael | Biplab K. Pramanik, Telcordia Technologies | bpramani@telcordia.com | 22.950 |  |  |  |  |
| 231 | 33.2 | Stage 1 - Requirements | 340d | 2002-05-30 A | 2003-09-17 | 85% | 51d | 2002-05-30 | 2003-09-17 | 340d | 555d | finish no earlier than 2003-09-17 | S1 | 2720h | 2312h | PRIOR-SR | Rel-6 |  | Michael | James J. Garrahan, Telcordia Technologies | bpramani@telcordia.com |  |  |  |  |  |
| 232 | 30.3 | Priority Multimedia Service | 131d? | 2003-03-28 | 2003-09-26 |  |  | 2003-03-28 | 2003-09-26 | 131d? | 548d | finish no earlier than 2003-09-26 | S1 | 1048h |  |  | Rel-6 |  |  |  |  |  |  |  |  |  |
| 233 | 30.4 | Priority service implementation guide | 131d? | 2003-03-28 A | 2003-09-26 | 85% | 19.65d? | 2003-03-28 | 2003-09-26 | 131d? | 548d | finish no earlier than 2003-09-26 | S1 | 1048h | 890.8h |  | Rel-6 |  |  | Biplab K. Pramanik, Telcordia Technologies | bpramani@telcordia.com | 22.952 |  |  |  |  |
| 234 | 34 | **Network Sharing** | 563.41d? | 2003-01-20 A | 2005-03-17 | 55% | 255.54d? | 2003-01-20 | 2003-12-19 | 240d? | 164.59d |  | S1 | 16886.5h | 9227.5h | NTShar | Rel-6 | TSG | Michael |  |  |  |  |  |  |  |
| 235 | 34.1 | Technical Report | 240d? | 2003-01-20 A | 2003-12-19 A | 100% |  | 2003-01-20 | 2003-12-19 | 240d? |  |  | S1 | 1920h | 1920h | NTShar-TR | Rel-6 |  | Michael |  |  | 22.951 |  |  |  |  |
| 236 | 31.2 | Stage 1 - CRs to implement Network Sharing | 240d? | 2003-01-20 A | 2003-12-19 A | 100% |  | 2003-01-20 | 2003-12-19 | 240d? |  | finish no earlier than 2003-12-19 | S1 | 1920h | 1920h | NTShar-CR | Rel-6 |  |  |  |  | 22.011, 22.101, 22.115, 22.129 |  |  |  |  |
| 237 | 31.3 | Stage 2 | 341d? | 2003-02-27 A | 2004-06-17 | 75% | 85.25d? | 2003-02-27 | 2003-12-19 | 212d? | 359d | finish no earlier than 2004-06-17 | S2 | 2728h | 2046h |  | Rel-6 |  |  |  |  |  |  |  |  |  |
| 238 | 31.4 | Network sharing - stage 3 | 339d? | 2003-05-23 A | 2004-09-08 | 4% | 325.44d? | 2003-05-23 | 2003-12-12 | 146d? | 300d | finish no earlier than 2004-09-08 | N1 | 2712h | 108.48h |  | Rel-6 | WG |  |  |  |  |  |  |  |  |
| 239 | 31.5 | Enhancement of the support of network sharing in the UTRAN | 389.41d | 2003-09-19 A | 2005-03-17 | 25% | 292.05d |  |  |  | 164.59d | finish no earlier than 2005-03-17 | R2 | 3115.25h | 778.81h | NTShar-UTRANEnh | Rel-6 | TSG | MCC_RAN | Anders Dahlén, TeliaSonera | Anders.Dahlen@TeliaSonera.com | TS25.401, TS25.413, TS25.331, TS25.304 | BB | 31018 | Active | 48 |
| 240 | 35 | **QoS Improvements** | 465d? | 2002-07-15 A | 2004-04-23 | 77% | 108.43d? | 2000-01-03 | 2003-12-19 | 1035d? | 398d |  | S2 | 10320h | 7913.5h | QoS1 | Rel-6 | TSG | Sang-Ui |  |  |  |  |  |  |  |
| 241 | 35.1 | FS on Dynamic Policy control enhancements for end-to-end QoS | 465d | 2002-07-15 A | 2004-04-23 | 90% | 46.5d | 2002-07-15 | 2003-12-19 | 375d | 398d | finish no earlier than 2004-04-23 | S2 | 3720h | 3348h | QoS1 | Rel-6 | TSG |  |  | Claire Mousset, Nortel |  |  |  |  |  |
| 242 | 32.2 | Definition of the Gq interface | 214d? | 2003-07-01 A | 2004-04-23 | 83% | 36.38d? | 2000-01-03 | 2000-01-03 | 1d? | 398d | finish no earlier than 2004-04-23 | S2 | 1712h | 1420.96h |  | Rel-6 |  |  | Janne Rinne (Nokia) |  |  |  |  |  |  |
| 243 | 32.3 | Gq interface specification for Dynamic Policy control enhancements – Stage 3 | 146d | 2003-08-29 A | 2004-03-19 | 25% | 109.5d |  |  |  | 423d | finish no earlier than 2004-03-19 | N3 | 1168h | 292h |  | Rel-6 | TSG |  | Anna Sillanpää, Nokia | Anna.Sillanpaai@nokia.com | 24,228, 29.207, 29.208 |  |  |  |  |

Notes:
- 218: Foreseen start and completion dates introduced by MCC (no indication at all on the WID)
- 221: SA3 acknowledge role in WI at SA3#20. Active contribution S3#24, S3#25. S3 WID approved SA#17
- 226: Active contribution S3#24, S3#25. WID approved SA#17
- 227: WID approved at CN#19......... / 14/05/2004requirements have been changed. WID updated. Work will be finished in CN#26

| ID | WBS | Task | Duration | Start | Finish | Complete | Remaining | Baseline start | Baseline finish | Baseline duration | Total slack | Constraint | Resources | Work | Actual work | Text1 | Text3 | Text4 | Text5 | Text6 | Text7 | Text8 |
| --- | --- | --- | --- | --- | --- | --- | --- | --- | --- | --- | --- | --- | --- | --- | --- | --- | --- | --- | --- | --- | --- | --- |
| 244 | 36 | **Support for subscriber certificates** | 722d? | 2002-02-25 A | 2004-11-30 | 37% | 454.94d? | 2002-02-25 | 2002-11-14 | 189d | 241d |  | S3 | 11408h | 4219.66h | SEC1-SC | 33.102 | Valtteri Niemi, Nokia | valtteri.niemi@nokia.com | Rel-6 | TSG | Maurice |
| 245 | 36.1 | Stage 1 | 144d | 2002-02-25 A | 2002-09-12 | 40% | 86.4d | 2002-02-25 | 2002-09-12 | 144d | 819d | finish no earlier than 2002-09-12 | S3 | 1152h | 460.8h |  |  |  |  | Rel-6 |  |  |
| 246 | 36.2 | Architecture review | 24d | 2002-10-14 A | 2002-11-14 A | 100% |  | 2002-10-14 | 2002-11-14 | 24d |  | finish no earlier than 2002-11-14 | S2 | 192h | 192h |  |  |  |  | Rel-6 |  |  |
| 247 | 33.3 | Stage 3 | 313d? | 2003-09-19 A | 2004-11-30 | 50% | 156.5d? |  |  |  | 241d | finish no earlier than 2004-11-30 | N4 | 2504h | 1252h | SEC1-SC |  | Lauri Laitinen, Nokia |  | Rel-6 |  | Kimmo |
| 248 | 33.4 | Stage 3 Ua & Ub interfaces | 223d? | 2003-11-03 A | 2004-09-08 | 10% | 200.7d? |  |  |  | 300d | finish no earlier than 2004-09-08 | N1 | 1784h | 178.4h |  |  |  |  | Rel-6 |  |  |
| 249 | 34 | **Rel-6 OSA enhancements** | 492d? | 2002-10-31 A | 2004-09-17 | 60% | 194.78d? | 2002-02-14 | 2003-12-19 | 481.85d? | 293d |  | S1 | 26023.2h | 14688.3h | OSA3 | 22.127, 29.198, 29.998 | Chelo ABARCA (Alcatel) | Chelo.Abarca@alcatel.fr | Rel-6 | TSG | Adrian |
| 250 | 34.1 | Scope of the Open Service Access Release 6 | 66d? | 2003-03-28 A | 2003-06-27 A | 100% |  | 2003-03-28 | 2003-06-27 | 66d? |  | finish no earlier than 2003-06-27 | S1 | 528h | 528h |  |  |  |  | Rel-6 | TSG |  |
| 251 | 34.2 | Multi Media Messaging function | 427d? | 2002-10-31 A | 2004-06-18 | 50% | 213.5d? | 2002-10-31 | 2003-12-19 | 297d? | 358d | finish no earlier than 2004-06-18 | N5 | 3416h | 1708h |  | 29.198, 29.998 |  |  | Rel-6 | TSG |  |
| 252 | 34.3 | Policy management extensions | 292d? | 2002-10-31 A | 2003-12-12 A | 100% |  | 2002-10-31 | 2003-12-19 | 297d? |  | finish no earlier than 2003-12-12 | N5 | 2336h | 2336h |  | 29.198, 29.998 |  |  | Rel-6 | TSG |  |
| 253 | 34.4 | TS on Presence and Availability Management (from the PRESNC WI) | 367d? | 2002-10-31 A | 2004-03-26 A | 100% |  | 2002-10-31 | 2003-12-19 | 297d? |  | finish no earlier than 2004-03-26 | N5 | 2936h | 2936h |  | 29.198-14 |  |  | Rel-6 | TSG |  |
| 254 | 34.5 | TR on Presence and Availability Management (from the PRESNC WI) | 492d | 2002-10-31 | 2004-09-17 |  |  |  |  |  | 293d | finish no earlier than 2004-09-17 | N5 | 3936h |  |  | 29.998-14 |  |  | Rel-6 | TSG |  |
| 255 | 34.6 | OSA interfaces at different levels of abstractions (Parlay X, Web services) | 245d? | 2003-07-14 A | 2004-06-18 | 90% | 24.5d? | 2003-03-14 | 2003-12-19 | 201d? | 358d | finish no earlier than 2004-02-27 | N5 | 1960h | 1764h |  | 29.199 |  |  | Rel-6 | TSG |  |
| 256 | 34.7 | Introduction of migration support mechanism | 290d? | 2002-10-31 A | 2003-12-10 A | 100% |  | 2003-03-14 | 2003-12-19 | 201d? |  | finish no earlier than 2003-12-12 | N5 | 2320h | 2320h |  | 29.198, 29.998 |  |  | Rel-6 | TSG |  |
| 257 | 34.8 | User Profile | 367d? | 2003-01-23 | 2004-06-18 |  |  | 2003-03-14 | 2003-12-19 | 201d? | 358d | start no earlier than 2003-01-23 | N5 | 2936h |  |  | 29.198, 29.998 |  |  | Rel-6 | TSG |  |
| 258 | 34.9 | Framework Function for Federation | 225d? | 2003-02-03 A | 2003-12-12 A | 100% |  | 2003-03-14 | 2003-12-19 | 201d? |  | finish no earlier than 2003-12-12 | N5 | 1800h | 1800h |  | 29.198, 29.998 |  |  | Rel-6 | TSG |  |
| 259 | 39 | **Addition of frequency bands to GSM** | 621d | 2002-06-28 A | 2004-11-12 | 4% | 596.04d | 2002-06-28 | 2003-08-29 | 306d | 253d |  | GP | 15320h | 615.64h | TAPS |  | Torben Themsen |  | Rel-6 | TSG | Paolo |
| 260 | 39.1 | **Addition of frequency bands to GSM – Changes to core specs** | 26d | 2002-11-15 A | 2002-12-20 A | 100% |  | 2002-11-15 | 2002-12-20 | 26d |  |  | G1 | 416h | 416h | TAPS-Specs |  | Torben Themsen |  | Rel-6 | TSG |  |
| 261 | 39.1.1 | Changes to core specs | 26d | 2002-11-15 A | 2002-12-20 A | 100% |  | 2002-11-15 | 2002-12-20 | 26d |  | finish no earlier than 2002-12-20 | G1 | 208h | 208h |  |  |  |  | Rel-6 |  |  |
| 262 | 39.2 | **Addition of frequency bands to GSM – Changes for conformance tests** | 621d | 2002-06-28 | 2004-11-12 |  |  | 2002-06-28 | 2003-08-29 | 306d | 253d |  | G4 | 9936h |  | TAPS-Conf |  | Torben Themsen |  | Rel-6 |  |  |
| 263 | 39.2.1 | 51.010-1 Add testing | 621d | 2002-06-28 | 2004-11-12 |  |  | 2002-06-28 | 2003-08-29 | 306d | 253d | finish no earlier than 2004-11-12 | G4 | 4968h |  |  |  |  |  | Rel-6 |  |  |
| 264 | 40 | **Seamless support of streaming services in A/Gb mode** | 1065d? | 2000-01-03 A | 2004-01-30 | 94% | 68.97d? | 2000-01-03 | 2003-12-19 | 1035d? | 458d |  | GP | 40840h | 37411.7h | SSStrea |  | José Luis Carrizo Martínez, Vodafone |  | Rel-6 | TSG | Paolo |
| 265 | 40.1 | **Identification of requirements for streaming** | 46d? | 2003-06-27 A | 2003-08-29 A | 100% |  | 2003-06-27 | 2003-06-27 | 1d? |  |  | G1 | 736h | 736h |  |  |  |  | Rel-6 |  |  |
| 266 | 36.1.1 | Requirements | 46d? | 2003-06-27 A | 2003-08-29 A | 100% |  | 2003-06-27 | 2003-06-27 | 1d? |  | finish no earlier than 2003-08-29 | G1 | 368h | 368h |  |  |  |  | Rel-6 |  |  |
| 267 | 40.2 | **Performance study of cell change mechanisms** | 955d? | 2000-01-03 A | 2003-08-29 A | 100% |  | 2000-01-03 | 2003-06-27 | 910d? |  |  | G1 | 30560h | 30560h |  |  |  |  | Rel-6 |  |  |
| 268 | 36.2.1 | Performance of NACC | 955d? | 2000-01-03 A | 2003-08-29 A | 100% |  | 2000-01-03 | 2003-06-27 | 910d? |  | finish no earlier than 2003-08-29 | G1 | 7640h | 7640h |  |  |  |  | Rel-6 |  |  |
| 269 | 36.2.2 | Performance of cell change in DTM for the PS domain | 955d? | 2000-01-03 A | 2003-08-29 A | 100% |  | 2000-01-03 | 2003-06-27 | 910d? |  | finish no earlier than 2003-08-29 | G1 | 7640h | 7640h |  |  |  |  | Rel-6 |  |  |
| 270 | 36.2.3 | Handover | 955d? | 2000-01-03 A | 2003-08-29 A | 100% |  | 2000-01-03 | 2003-06-27 | 910d? |  | finish no earlier than 2003-08-29 | G1 | 7640h | 7640h |  |  |  |  | Rel-6 |  |  |

Notes:
- 244: Approved at SA#14. This may require BBs from CN1, CN4, SA5 and T3
- 245: Contribution received S3#24, S3#25
- 247: WID approved at CN#21......... / 14/05/2004 CN: Work can not be finished before CN#26
- 249: NP-040144 Rev WID replaces NP-040068.
- 253: N5#26: Split WI into TS & TR.
- 254: N5#26:TR Completion 09/04; consistent with CN1 delayed Rel-6 completion.
- 255: N5#26: Will be submitted to CN#24 for Approval only if Rel-6 "freezing" is 06/2004.
- 257: N5#24&25&26: Still Pending input from SA1/2.
- 260: Ready
- 262: Not started
- 265: Started
- 267: Started

| ID | WBS | Task | Duration | Start | Finish | Complete | Remaining | Baseline start | Baseline finish | Baseline duration | Total slack | Constraint | Resources | Work | Actual work | Text6 | Text3 | Text4 | Text5 | Text1 | Text7 | Text8 | Text2 |
| --- | --- | --- | --- | --- | --- | --- | --- | --- | --- | --- | --- | --- | --- | --- | --- | --- | --- | --- | --- | --- | --- | --- | --- |
| 271 | 40.3 | **Reduction of service interruption times and packet loss during mobility procedures** | 106d? | 2003-06-27 A | 2003-11-21 | 99% | 0d? | 2003-06-27 | 2003-06-27 | 1d? | 0d |  | G2 | 4240h | 3396h | Rel-6 |  |  |  |  |  |  |  |
| 272 | 36.3.1 | Optimisations of existing mechanisms/procedures | 106d? | 2003-06-27 A | 2003-11-21 A | 100% |  | 2003-06-27 | 2003-06-27 | 1d? |  | finish no earlier than 2003-11-21 | G2 | 848h | 848h | Rel-6 |  |  |  |  |  |  |  |
| 273 | 36.3.2 | Inter-system NACC | 106d? | 2003-06-27 A | 2003-11-21 A | 100% |  | 2003-06-27 | 2003-06-27 | 1d? |  | finish no earlier than 2003-11-21 | G2 | 848h | 848h | Rel-6 |  |  |  |  |  |  |  |
| 274 | 36.3.3 | PS Handover (within GERAN and between GERAN and UTRAN) | 106d? | 2003-06-27 A | 2003-11-21 A | 100% |  | 2003-06-27 | 2003-06-27 | 1d? |  | finish no earlier than 2003-11-21 | G2 | 848h | 848h | Rel-6 |  |  |  |  |  |  |  |
| 275 | 36.3.4 | Dependency to other features | 106d? | 2003-06-27 A | 2003-11-21 A | 100% |  | 2003-06-27 | 2003-06-27 | 1d? |  | finish no earlier than 2003-11-21 | G2 | 848h | 848h | Rel-6 |  |  |  |  |  |  |  |
| 276 | 40.5 | **MS conformance testing** | 31d? | 2003-12-19 A | 2004-01-30 A | 100% |  | 2003-12-19 | 2003-12-19 | 1d? |  |  | G3 | 248h | 248h | Rel-6 |  |  |  |  |  |  |  |
| 277 | 36.4.1 | MS conformance tests | 31d? | 2003-12-19 A | 2004-01-30 A | 100% |  | 2003-12-19 | 2003-12-19 | 1d? |  | finish no earlier than 2004-01-30 | G4,G5 | 248h | 248h | Rel-6 |  |  |  |  |  |  |  |
| 278 | 36.5 | GERAN A/Gb mode security enhancements | 261d? | 2002-09-26 A | 2003-09-25 | 10% | 234.9d? | 2002-09-26 | 2003-09-25 | 261d? | 549d | finish no earlier than 2003-09-25 | S3 | 2088h | 208.8h | Rel-6 | 33.102 | Peter Howard, Vodafone | peter.howard@vodafone.com |  |  |  |  |
| 279 | 41 | Performance characterisation of default codecs for PS conversational multimedia application | 455d | 2002-09-13 A | 2004-06-10 | 90% | 45.5d | 2002-09-13 | 2003-09-26 | 271d | 364d | finish no earlier than 2004-06-10 | S4 | 3640h | 3276h | Rel-6 | TR 26.935 | Pasi Ojala (Nokia) | pasi.s.ojala@nokia.com | CODCAR | TSG | Paolo |  |
| 280 | 42 | DELETE: Study of Feature Interactions Requirements | 82d | 2002-11-08 A | 2003-03-03 | 20% | 65.6d | 2002-11-08 | 2003-03-03 | 82d | 697d | start no earlier than 2002-11-08 | S1 | 656h | 131.2h | Rel-6 | TR 21.xyz |  |  | FINTER | TSG | Michael |  |
| 281 | 43 | Study on Privacy Capability | 82d | 2002-11-08 A | 2003-03-03 | 85% | 12.3d | 2002-11-08 | 2003-03-03 | 82d | 697d | start no earlier than 2002-11-08 | S1 | 656h | 557.6h | Rel-6 | TR 21.xyz | Liz Daniel, Lucent |  | PrivCap | TSG | Michael |  |
| 282 | 44 | **OAM&P** | 585d? | 2002-09-12 A | 2004-12-08 | 67% | 190.64d? | 2002-05-21 | 2004-03-18 | 477.3d? | 235d |  | S5 | 28341.6h | 17376.1h | Rel-6 | 32-series | Michael TRUSS (Motorola) | Michael.Truss@MOTOROLA.COM | OAM | TSG | Adrian |  |
| 283 | 44.1 | Principles, high level Requirements and Architecture | 526d | 2002-09-12 A | 2004-09-16 | 75% | 131.5d | 2002-09-12 | 2004-03-18 | 396d | 294d | finish no earlier than 2004-09-16 | S5 | 4208h | 3156h | Rel-6 | 32.101, 32.102 | Michael TRUSS (Motorola) | Michael.Truss@MOTOROLA.COM | OAM-AR | TSG |  | BCaM |
| 284 | 44.2 | Performance Management | 526d | 2002-09-12 A | 2004-09-16 | 75% | 131.5d | 2002-09-12 | 2004-03-18 | 396d | 294d | finish no earlier than 2004-09-16 | S5 | 4208h | 3156h | Rel-6 | 32.41x, 52.402 | Christian TOCHE (Nortel Networks) | toche@NORTELNETWORKS.COM | OAM-PM | TSG |  | BCaM |
| 285 | 44.4 | Network Infrastructure Management | 526d | 2002-09-12 A | 2004-09-16 | 75% | 131.5d | 2002-09-12 | 2004-03-18 | 396d | 294d | finish no earlier than 2004-09-16 | S5 | 4208h | 3156h | Rel-6 | 32.15x, 32.3/6/7xy | Thomas TOVINGER (Ericsson) | Thomas.Tovinger@emw.ericsson.se | OAM-NIM | TSG |  |  |
| 286 | 44.5 | **Trace Management** | 579d? | 2002-09-20 A | 2004-12-08 | 55% | 257.94d? | 2003-06-06 | 2003-09-19 | 76d | 235d |  | S5 | 11160h | 4835.68h | Rel-6 | 32.42x, 52.008 | Kari RÖNKÄ (Nokia) | kari.t.ronka@nokia.com | OAM-Trace | TSG |  |  |
| 287 | 40.4.1 | Subscriber and UE trace management | 520d | 2002-09-20 A | 2004-09-16 | 75% | 130d |  |  |  | 294d | finish no earlier than 2004-09-16 | S5 | 4160h | 3120h | Rel-6 | 32.42x, 52.008 | Kari RÖNKÄ (Nokia) | kari.t.ronka@nokia.com | OAM-Trace | TSG |  |  |
| 288 | 40.4.2 | Subscriber and equipment trace in UTRAN | 268d? | 2003-06-06 A | 2004-06-15 | 60% | 107.2d? | 2003-06-06 | 2003-09-19 | 76d? | 361d | finish no earlier than 2004-06-15 | R3 | 2144h | 1286.4h | Rel-6 |  | Yann Sehedi, Nortel | sehedic@nortelnetworks.com | OAM-Trace-RAN | TSG | MCC_RAN |  |
| 289 | 40.4.3 | SIP enhancements for trace | 213d? | 2004-02-16 A | 2004-12-08 | 2% | 208.74d? |  |  |  | 235d | finish no earlier than 2004-12-08 | N1 | 1704h | 34.08h | Rel-6 |  |  |  |  |  |  |  |
| 290 | 41 | **Charging Management** | 476d? | 2002-11-21 A | 2004-09-16 | 75% | 120.06d? | 2002-11-21 | 2004-03-18 | 346d? | 294d |  | S5 | 15840h | 10610.5h | Rel-6 | 32.2xy | Karl-Heinz NENNER (T-Mobile) | karl-heinz.nenner@t-mobile.de | CH | TSG | Adrian |  |
| 291 | 41.1 | Charging Management for Bearer level | 390d? | 2003-03-21 A | 2004-09-16 | 75% | 97.5d? | 2002-11-22 | 2004-03-18 | 345d? | 294d | finish no earlier than 2004-09-16 | S5 | 3120h | 2340h | Rel-6 |  | Benni ALEXANDER (Nokia) |  | CH-BC | TSG |  |  |
| 292 | 41.2 | Charging Management for the IMS | 390d? | 2003-03-21 A | 2004-09-16 | 75% | 97.5d? | 2002-11-22 | 2004-03-18 | 345d? | 294d | finish no earlier than 2004-09-16 | S5 | 3120h | 2340h | Rel-6 |  | Patrik TEPPO (Ericsson) |  | CH-IC | TSG |  |  |
| 293 | 41.3 | Charging Management for the Service domain | 390d? | 2003-03-21 A | 2004-09-16 | 75% | 97.5d? | 2002-11-22 | 2004-03-18 | 345d? | 294d | finish no earlier than 2004-09-16 | S5 | 3120h | 2340h | Rel-6 |  | Gerald GÖRMER (Siemens) |  | CH-SC | TSG |  |  |
| 294 | 41.4 | Overall architectural aspects of IP flow based bearer level charging | 334d? | 2002-11-21 A | 2004-03-02 | 74% | 86.84d? | 2002-11-21 | 2003-09-26 | 222d? | 436d | finish no earlier than 2004-03-02 | S2 | 2672h | 1977.28h | Rel-6 |  |  |  | CH-FBC |  |  |  |

Notes:
- 271: Completed at GERAN#17
- 276: Closed, no work needed
- 277: Closed, no work needed
- 278: Possible changes to 33.102 or new specification needed.
- 282: az: SA#23 TSG approval 06/04->09/04
- 290: az: SA#23 TSG approval 06/04->09/04

| ID | WBS | Task | Duration | Start | Finish | Complete | Remaining | Baseline start | Baseline finish | Baseline duration | Total slack | Constraint | Resources | Work | Actual work | Text1 | Text2 | Text6 | Text7 | Text8 | Text9 | Text4 | Text5 | Text3 |
| --- | --- | --- | --- | --- | --- | --- | --- | --- | --- | --- | --- | --- | --- | --- | --- | --- | --- | --- | --- | --- | --- | --- | --- | --- |
| 295 | 13 | **Rel-6 UICC/USIM enhancements and interworking** | 889d | 2000-09-25 A | 2004-02-19 | 99% | 8.4d | 2000-09-25 | 2003-09-17 | 778d | 444d |  | T3 | 26760h | 23288.6h | USAT1 | Ter | Rel-6 | TSG | Claus | 1800 |  |  |  |
| 296 | 13.1 | **UICC API** | 502d | 2002-03-20 A | 2004-02-19 | 98% | 10.73d | 2002-03-20 | 2003-09-17 | 391d | 444d |  | T3 | 8584h | 8400.59h | USAT1-API | Ter | Rel-6 |  |  | 1802 |  |  |  |
| 297 | 13.1.1 | Java API Test specification | 59d | 2002-03-20 A | 2002-06-10 A | 100% |  | 2002-03-20 | 2002-09-20 | 133d |  | finish no earlier than 2002-09-20 | T3 | 472h | 472h |  |  | Rel-6 |  |  |  | Mario Pérez (Microelectrónica Española) |  |  |
| 298 | 13.1.2 | Java API Test specification (TS 43.019 Rel-5) | 268d | 2002-05-30 A | 2003-06-09 A | 100% |  | 2002-05-30 | 2003-09-17 | 340d |  | finish no earlier than 2003-09-17 | T3 | 2144h | 2144h |  |  | Rel-6 |  |  |  | Mario Pérez (Microelectrónica Española) |  |  |
| 299 | 42.1.3 | 2G/3G Java Card™ API based applet interworking | 244d | 2003-03-17 A | 2004-02-19 | 95% | 12.2d |  |  |  | 444d | finish no earlier than 2004-02-19 | T3 | 1952h | 1854.4h | USAT1-API |  | Rel-6 | TSG | Claus |  | Stéphane Andrau-Oberthur Card Systems |  |  |
| 300 | 42.2 | **Rel-6 USIM toolkit enhancements** | 525d | 2000-09-25 A | 2002-09-27 | 99% | 0d | 2000-09-25 | 2002-09-27 | 525d | 0d |  | T3 | 14160h | 10910h |  |  | Rel-6 |  | Claus |  |  |  |  |
| 301 | 42.2.1 | **C SIM API** | 525d | 2000-09-25 A | 2002-09-27 A | 100% |  | 2000-09-25 | 2002-09-27 | 525d |  |  | T3 | 9960h | 9960h | USAT1-API-MULTOS | Ter | Rel-6 | TSG |  | 2031 |  |  |  |
| 302 | 42.2.1.1 | Specification | 525d | 2000-09-25 A | 2002-09-27 A | 100% |  | 2000-09-25 | 2002-09-27 | 525d |  | finish no earlier than 2002-09-27 | T3 | 4200h | 4200h |  | Ter | Rel-6 | TSG |  | 2032 | Neil Livingston – Aspects Software |  |  |
| 303 | 42.2.1.2 | Test specification | 195d | 2001-01-01 A | 2001-09-28 A | 100% |  | 2001-01-01 | 2001-09-28 | 195d |  | finish no earlier than 2001-09-28 | T3 | 1560h | 1560h |  | Ter | Rel-6 | TSG |  | 2033 | Neil Livingston – Aspects Software |  |  |
| 304 | 43 | **Packet Switched Streaming Services Rel-6** | 479d? | 2002-11-18 A | 2004-09-16 | 79% | 100.89d? | 2002-11-18 | 2003-12-19 | 285d? | 294d |  | S4 | 8200h | 6472.89h | PSSrel6 |  | Rel-6 | TSG | Paolo |  | Olle Franceschi (Ericsson) | olle.franceschi@ericsson.com |  |
| 305 | 43.1 | Stage 1 | 86d? | 2002-11-18 A | 2003-03-17 A | 100% |  | 2002-11-18 | 2003-03-17 | 86d? |  | finish no earlier than 2003-03-17 | S1 | 688h | 688h |  |  | Rel-6 | TSG |  |  |  |  | 22.233 |
| 306 | 43.2 | Stage 3 | 460d? | 2002-12-13 A | 2004-09-16 | 75% | 115d? | 2002-12-13 | 2003-12-19 | 266d? | 294d | finish no earlier than 2004-09-16 | S4 | 3680h | 2760h | PSSrel6-Stage3 |  | Rel-6 | WG | Paolo |  | Olle Franceschi (Ericsson) | olle.franceschi@ericsson.com | 26.233, 26.234, 26.244, 26.245, 26.246 |
| 307 | 44 | AMR-WB extension for high audio quality | 390d | 2002-12-13 A | 2004-06-10 | 75% | 97.5d | 2002-12-13 | 2003-09-26 | 206d | 364d | finish no earlier than 2004-06-10 | S4 | 3120h | 2340h | AMRWB+ |  | Rel-6 | TSG | Paolo |  | Janne Vainio (Nokia) | janne.m.vainio@nokia.com |  |
| 308 | 45 | Codec Enhancements for Packet Switched Conversational Multimedia Applications | 133d? | 2004-03-16 | 2004-09-16 |  |  |  |  |  | 294d | finish no earlier than 2004-09-16 | S4 | 1064h |  | CEPSCM |  | Rel-6 | WG | Paolo |  | Miska Hannuksela (Nokia) | miska.hannuksela@nokia.com | 26.235, 26.236 |
| 309 | 46 | 3G-324M Improvements | 133d? | 2004-03-16 | 2004-09-16 |  |  |  |  |  | 294d | finish no earlier than 2004-09-16 | S4 | 1064h |  | 3G-324MI |  | Rel-6 | WG | Paolo |  | Bo Burman, Ericsson | bo.burman@ericsson.com | 26.111, 26.911 |
| 310 | 47 | Single Antenna Receiver Interference Cancellation (SAIC) | 330.92d? | 2002-11-15 A | 2004-04-23 | 80% | 66.18d? | 2002-11-15 | 2003-11-21 | 220.92d? | 398d | finish no earlier than 2004-04-23 | GP; G1 | 5294.72h | 4235.77h | SAIC |  | Rel-6 | TSG |  |  | Marc Grant, Cingular Wireless |  |  |
| 311 | 48 | **Support of Conversational Services in A/Gb mode via the PS domain** | 406d? | 2003-02-07 A | 2004-08-27 | 24% | 308.17d? | 2003-02-07 | 2004-04-23 | 316d? | 308d |  | GP | 12792h | 1784.93h | SCSAGB |  | Rel-6 | TSG |  |  | David Bladsjö, Ericsson | david.bladsjo@ericsson.com |  |
| 312 | 48.1 | Creation of a TR | 206d? | 2003-02-07 A | 2003-11-21 A | 100% |  | 2003-02-07 | 2003-11-21 | 206d? |  | finish no earlier than 2003-11-21 | GP | 1648h | 1648h | SCSAGB-TR |  | Rel-6 | TSG |  |  | David Bladsjö, Ericsson |  |  |
| 313 | 48.2 | Stage 2 | 111d? | 2003-11-21 A | 2004-04-23 | 10% | 99.9d? | 2003-11-21 | 2004-04-23 | 111d? | 398d | finish no earlier than 2004-04-23 | GP | 888h | 88.8h | SCSAGB-Stage2 |  | Rel-6 | TSG |  |  | David Bladsjö, Ericsson |  |  |
| 314 | 48.3 | Radio Channel Support | 146d? | 2004-02-06 | 2004-08-27 |  |  | 2004-02-06 | 2004-04-23 | 56d? | 308d | finish no earlier than 2004-08-27 | GP | 1168h |  | SCSAGB-RCS |  | Rel-6 | TSG |  |  | David Bladsjö, Ericsson |  |  |
| 315 | 48.4 | Definition of radio resource management functionality | 146d? | 2004-02-06 | 2004-08-27 |  |  | 2004-02-06 | 2004-04-23 | 56d? | 308d | finish no earlier than 2004-08-27 | GP; G2 | 2336h |  | SCSAGB-RRM |  | Rel-6 | TSG |  |  | David Bladsjö, Ericsson |  |  |
| 316 | 48.5 | PS Handover | 146d? | 2004-02-06 | 2004-08-27 |  |  | 2004-02-06 | 2004-04-23 | 56d? | 308d | finish no earlier than 2004-08-27 | GP | 1168h |  | SCSAGB-PSH |  | Rel-6 | TSG |  |  | David Bladsjö, Ericsson |  |  |
| 317 | 48.6 | Modifications to FLO | 146d? | 2004-02-06 | 2004-08-27 |  |  | 2004-02-06 | 2004-04-23 | 56d? | 308d | finish no earlier than 2004-08-27 | GP; G2 | 2336h |  | SCSAGB-FLO |  | Rel-6 | TSG |  |  | David Bladsjö, Ericsson |  |  |
| 318 | 49 | **Enhancement of dialled service for CAMEL** | 199d | 2003-03-28 A | 2003-12-31 A | 100% |  | 2003-03-28 | 2003-09-19 | 126d? |  |  | S1 | 3184h | 3184h | EDCAMEL |  | Rel-6 | TSG | Andrijana |  | Craig Bishop, Samsung Electronics Research Institute |  |  |
| 319 | 49.1 | Stages 2 and 3 | 199d | 2003-03-28 A | 2003-12-31 A | 100% |  | 2003-03-28 | 2003-09-19 | 126d |  | finish no earlier than 2003-09-19 | N2 | 1592h | 1592h |  |  | Rel-6 |  |  |  |  |  |  |
| 320 | 50 | Bandwidth and resource savings in CS networks | 273d? | 2003-06-01 A | 2004-06-16 | 70% | 81.9d? | 2003-06-23 | 2003-11-25 | 112d? | 360d | finish no earlier than 2004-06-16 | S2 | 2184h | 1528.8h | CSSAVE |  | Rel-6 |  |  |  |  |  | TR 23.977 |
| 321 | 51 | FS on (U)SIM Security Reuse by Peripheral Devices on Local Interfaces | 127d? | 2003-07-03 A | 2003-12-26 | 5% | 120.65d? | 2003-07-03 | 2003-12-26 | 127d? | 483d | finish no earlier than 2003-12-26 | S3 | 1016h | 50.8h |  |  | Rel-6 | TSG | Maurice |  | Raziq Yaqub, Toshiba America Research Inc. | ryaqub@tari.toshiba.com |  |

Notes:
- 296: 8/3/2001: test spec is based on R99 core spec, so deleted from Workplan
- 305: 2nd resp SA4
- 313: Started
- 314: Not started
- 315: Not started
- 316: Not started
- 317: Not started
- 321: Approved TSG#20

| ID | WBS | Task | Duration | Start | Finish | Complete | Remaining | Baseline start | Baseline finish | Baseline duration | Total slack | Constraint | Resources | Work | Actual work | Text1 | Text4 | Text6 | Text7 | Text8 | Text5 |
| --- | --- | --- | --- | --- | --- | --- | --- | --- | --- | --- | --- | --- | --- | --- | --- | --- | --- | --- | --- | --- | --- |
| 322 | 52 | **Multiple TBF in A/Gb mode** | 581d? | 2002-04-05 A | 2004-06-25 | 65% | 201.05d? | 2002-04-05 | 2004-01-30 | 476d? | 353d |  | GP; G2 | 37368h | 27408.6h | MULTBF | Gunnar Mildh, Ericsson | Rel-6 | TSG | Paolo |  |
| 323 | 52.1 | **Multiple TBF in A/Gb mode** | 366d? | 2002-04-05 A | 2003-08-29 A | 100% |  | 2002-04-05 | 2003-08-29 | 366d? |  |  | GP; G2 | 23424h | 23424h | MULTBF-Agbmode | Gunnar Mildh, Ericsson | Rel-6 | TSG |  |  |
| 324 | 52.1.1 | Multiple TBF Concept paper | 366d? | 2002-04-05 A | 2003-08-29 A | 100% |  | 2002-04-05 | 2003-08-29 | 366d? |  | finish no earlier than 2003-08-29 | GP; G2 | 5856h | 5856h |  |  | Rel-6 |  |  |  |
| 325 | 52.1.2 | Multiple TBF Stage 2 (43.064) CRs | 366d? | 2002-04-05 A | 2003-08-29 A | 100% |  | 2002-04-05 | 2003-08-29 | 366d? |  | finish no earlier than 2003-08-29 | GP; G2 | 5856h | 5856h |  |  | Rel-6 |  |  |  |
| 326 | 52.1.3 | Multiple TBF Stage 3 (44.060) CRs | 366d? | 2002-04-05 A | 2003-08-29 A | 100% |  | 2002-04-05 | 2003-08-29 | 366d? |  | finish no earlier than 2003-08-29 | GP; G2 | 5856h | 5856h |  |  | Rel-6 |  |  |  |
| 327 | 52.2 | Multiple TBF in A/Gb mode – MS testing | 581d? | 2002-04-05 | 2004-06-25 |  |  | 2002-04-05 | 2004-01-30 | 476d? | 353d | finish no earlier than 2004-06-25 | G3 | 4648h |  | MULTBF-Testing | Gunnar Mildh, Ericsson | Rel-6 | TSG | Paolo |  |
| 328 | 53 | **Alignment between the test-regimes for GERAN capable MS** | 171d? | 2003-08-29 A | 2004-04-23 | 80% | 34.2d? |  |  |  | 398d |  | G3 | 2736h | 1094.4h | ALTERE | Toubassi, Ericsson | Rel-6 | TSG | Michael |  |
| 329 | 53.1 | Determine the controversial test cases in the different test regimes and align them with 3GPP GERAN test specifications. Such test cases to be added to TS 51.010. | 171d? | 2003-08-29 A | 2004-04-23 | 80% | 34.2d? |  |  |  | 398d | finish no earlier than 2004-04-23 | G3 | 1368h | 1094.4h | ALTERE-TC |  | Rel-6 | TSG |  |  |
| 330 | 54 | Addition of U-TDOA in the CS domain | 111d? | 2003-11-21 A | 2004-04-23 | 90% | 11.1d? |  |  |  | 398d | finish no earlier than 2004-04-23 | GP | 888h | 799.2h | UTDOACS | Bob Gross, Rhys Robinson, TruePosition, Inc. | Rel-6 | TSG | Paolo | rlgross@trueposition.com |
| 331 | 55 | Addition of U-TDOA in the PS domain | 256d? | 2003-06-27 A | 2004-11-12 | 5% | 243.2d? |  |  |  | 253d | finish no earlier than 2004-11-12 | GP | 2048h | 102.4h | UTDOAPS | Bob Gross, Rhys Robinson, TruePosition, Inc. | Rel-6 | TSG | Paolo | rlgross@trueposition.com |
| 332 | 56 | **Advanced Receiver Performance** | 256d? | 2003-11-21 A | 2004-11-12 | 18% | 210.99d? |  |  |  | 253d |  | GP | 9120h | 992.53h | ARP | Tommy Bysted, Nokia | Rel-6 | TSG | Paolo | tommy.bysted@nokia.com |
| 333 | 56.1 | ARP test scenarios | 111d? | 2003-11-21 A | 2004-04-23 | 20% | 88.8d? |  |  |  | 398d | finish no earlier than 2004-04-23 | GP | 888h | 177.6h | ARP-TS | Tommy Bysted, Nokia | Rel-6 | TSG | Paolo | tommy.bysted@nokia.com |
| 334 | 56.2 | **ARP for GMSK modulated voice services** | 101d? | 2004-02-06 A | 2004-06-25 | 15% | 85.85d? |  |  |  | 353d |  | GP | 2424h | 242.4h | ARP-GMSK | Tommy Bysted, Nokia | Rel-6 | TSG | Paolo | tommy.bysted@nokia.com |
| 335 | 56.2.1 | Performance requirements in 45.005 | 101d? | 2004-02-06 A | 2004-06-25 | 15% | 85.85d? |  |  |  | 353d | finish no earlier than 2004-06-25 | GP | 808h | 121.2h | ARP-GMSK-Perf |  | Rel-6 | TSG |  |  |
| 336 | 56.2.2 | Radio subsystem link control in 45.008 | 101d? | 2004-02-06 A | 2004-06-25 | 15% | 85.85d? |  |  |  | 353d | finish no earlier than 2004-06-25 | GP | 808h | 121.2h | ARP-GMSK-LC |  | Rel-6 | TSG |  |  |
| 337 | 56.3 | **ARP for GPRS and EGPRS MCS1-MCS4** | 101d? | 2004-02-06 A | 2004-06-25 | 10% | 90.9d? |  |  |  | 353d |  | GP | 2424h | 161.6h | ARP-GPRSE | Tommy Bysted, Nokia | Rel-6 | TSG | Paolo | tommy.bysted@nokia.com |
| 338 | 56.3.1 | Performance requirements in 45.005 | 101d? | 2004-02-06 A | 2004-06-25 | 10% | 90.9d? |  |  |  | 353d | start no earlier than 2004-02-06 | GP | 808h | 80.8h | ARP-GPRSE-Perf |  | Rel-6 | TSG |  |  |
| 339 | 56.3.2 | Radio subsystem link control in 45.008 | 101d? | 2004-02-06 A | 2004-06-25 | 10% | 90.9d? |  |  |  | 353d | start no earlier than 2004-02-06 | GP | 808h | 80.8h | ARP-GPRSE-LC |  | Rel-6 | TSG |  |  |
| 340 | 56.4 | ARP Capability signalling | 111d? | 2003-11-21 A | 2004-04-23 | 40% | 66.6d? |  |  |  | 398d | finish no earlier than 2004-04-23 | GP | 888h | 355.2h | ARP-CAPSIG | Tommy Bysted, Nokia | Rel-6 | TSG | Paolo | tommy.bysted@nokia.com |
| 341 | 56.5 | GERAN MS Conformance test for ARP | 56d? | 2004-08-27 A | 2004-11-12 | 5% | 53.2d? |  |  |  | 253d | finish no earlier than 2004-11-12 | G3 | 448h | 22.4h | ARP-ConfTest | Tommy Bysted, Nokia | Rel-6 | TSG | Michael | tommy.bysted@nokia.com |
| 342 | 57 | **Reduction of PS service interruption in Dual Transfer Mode** | 256d? | 2003-11-21 A | 2004-11-12 | 48% | 133.83d? |  |  |  | 253d |  | G2 | 5808h | 1818.58h | PSintDTM | Toby Proctor, Siemens | Rel-6 | TSG | Gert | toby.proctor@roke.co.uk |
| 343 | 57.1 | Use case and requirement definition | 111d? | 2003-11-21 A | 2004-04-23 A | 100% |  |  |  |  |  | finish no earlier than 2004-04-23 | G2 | 888h | 888h | PSintDTM-Req | Toby Proctor, Siemens | Rel-6 | TSG | Gert | toby.proctor@roke.co.uk |
| 344 | 57.2 | Performance Study of Current Procedures | 111d? | 2003-11-21 A | 2004-04-23 A | 100% |  |  |  |  |  | start no earlier than 2003-11-21 | G2 | 888h | 888h | PSintDTM-Perf | Toby Proctor, Siemens | Rel-6 | TSG | Gert | toby.proctor@roke.co.uk |
| 345 | 57.3 | Reduction of service interruption times and packet loss during Dual Transfer Mode and mobility procedures | 46d? | 2004-04-23 A | 2004-06-25 | 5% | 43.7d? |  |  |  | 353d | finish no earlier than 2004-06-25 | G2 | 368h | 18.4h | PSintDTM-Reduct | Toby Proctor, Siemens | Rel-6 | TSG | Gert | toby.proctor@roke.co.uk |
| 346 | 57.4 | MS Conformance testing | 101d? | 2004-06-25 | 2004-11-12 |  |  |  |  |  | 253d | finish no earlier than 2004-11-12 | G3 | 808h |  | PSintDTM-ConfMS |  | Rel-6 | TSG | Michael |  |
| 347 | 57.5 | BTS Conformance testing | 101d? | 2004-06-25 | 2004-11-12 |  |  |  |  |  | 253d | finish no earlier than 2004-11-12 | G3 | 808h |  | PSintDTM-ConfBTS |  | Rel-6 | TSG | Michael |  |
| 348 | 58 | CAMEL prepay interworking with SCUDIF | 206d | 2003-12-08 A | 2004-09-20 | 5% | 195.7d |  |  |  | 292d |  | N2 | 1648h | 82.4h | SCCAMEL |  | Rel-6 |  |  |  |

Notes:
- 326: Not started
- 327: Not started
- 329: Started
- 330: Started
- 331: Started
- 333: Started
- 334: Started
- 335: Started
- 336: Started
- 337: Started
- 338: Started
- 339: Started
- 340: Started
- 341: Started
- 343: Started
- 344: Started
- 345: Started
- 346: Not started
- 347: Not started

| ID | WBS | Task | Duration | Start | Finish | Complete | Remaining | Baseline start | Baseline finish | Baseline duration | Total slack | Constraint | Resources | Work | Actual work | Text1 | Text4 | Text6 | Text7 | Text8 | Text3 |
| --- | --- | --- | --- | --- | --- | --- | --- | --- | --- | --- | --- | --- | --- | --- | --- | --- | --- | --- | --- | --- | --- |
| 349 | 59 | **Circuit Switched Video and Voice Service Improvements** | 199d | 2004-01-12 A | 2004-10-14 | 9% | 180.91d | 2003-03-28 | 2003-09-19 | 126d | 274d |  | S1 | 5810h | 796h | CS_VSS | John Watson, Vodafone Group | Rel-6 | TSG | Michael |  |
| 350 | 59.1 | Stage 1 - Requirements | 199d | 2004-01-12 A | 2004-10-14 | 25% | 149.25d | 2004-01-12 | 2004-10-14 | 199d | 274d | finish no earlier than 2004-10-14 | S1 | 1592h | 398h |  | John Watson, Vodafone Group | Rel-6 | TSG | Michael |  |
| 351 | 59.2 | CN3 Part | 149.25d | 2004-01-12 | 2004-10-14 |  |  | 2004-02-20 | 2004-10-14 | 120.25d | 274d | start no earlier than 2004-01-12 | N3 | 1194h |  |  |  | Rel-6 | TSG | DavidB |  |
| 352 | 59.3 | GERAN2 Part | 199d | 2004-01-12 | 2004-10-14 |  |  | 2004-02-20 | 2004-02-20 | 1d | 274d | start no earlier than 2004-01-12 | G2 | 1592h |  |  |  | Rel-6 | TSG | Gert |  |
| 353 | 60 | **Access Class Barring and Overload Protection** | 67d? | 2004-03-15 | 2004-06-15 |  |  |  |  |  | 361d |  | S2 | 2680h |  | ACBOP | Chris Pudney, Vodafone |  | TSG | Sang-Ui |  |
| 354 | 60.1 | TR on Stage 2 | 67d? | 2004-03-15 | 2004-06-15 |  |  |  |  |  | 361d | finish no earlier than 2004-06-15 | S2 | 536h |  |  |  |  | TSG |  |  |
| 355 | 60.2 | Extra access class barring information in RAN | 67d? | 2004-03-15 | 2004-06-15 |  |  |  |  |  | 361d | start no earlier than 2004-03-15 | RP | 536h |  |  |  |  | TSG |  | 25.331 |
| 356 | 60.3 | Extra access class barring information in GERAN | 67d? | 2004-03-15 | 2004-06-15 |  |  |  |  |  | 361d | start no earlier than 2004-03-15 | GP | 536h |  |  |  |  | TSG |  | 44.018 |
| 357 | 60.4 | Potential impact on Iu interface Overload functionality | 67d? | 2004-03-15 | 2004-06-15 |  |  |  |  |  | 361d | start no earlier than 2004-03-15 | RP | 536h |  |  |  |  | TSG |  | 25.413 |
| 358 | 61 | **Combining CS bearers with IMS** | 67d? | 2004-03-15 | 2004-06-15 |  |  |  |  |  | 361d |  | S2 | 1072h |  | CSI | Mark Watson, Nortel Networks |  | TSG | Sang-Ui |  |
| 359 | 61.1 | TR on Alternative Architectures for Combining CS Bearers with IMS | 67d? | 2004-03-15 | 2004-06-15 |  |  |  |  |  | 361d | start no earlier than 2004-03-15 | S2 | 536h |  |  |  |  | TSG |  |  |
